# Don Funk Incorrect 2-6

How a schedule from MS Project changed from version to version. A marks actual dates.

## Version 1 (saved 2013-05-28, file damakrishnasairamproject2-6-mpp)

| ID | WBS | Task | Duration | Start | Finish | Predecessors | Total float |
| --- | --- | --- | --- | --- | --- | --- | --- |
| 1 | 1 | **Pre-Production** | 95d | 2016-01-04 | 2016-05-16 |  | 0d |
| 2 |  | Pre-Production begins | 0d | 2016-01-04 | 2016-01-04 |  | 0d |
| 3 |  | Review screenplay | 3w | 2016-01-04 | 2016-01-25 | 2 | 0d |
| 4 |  | Develop scene blocking and schedule | 1w | 2016-01-26 | 2016-02-01 | 3 | 0d |
| 5 |  | Develop production layouts | 1mo | 2016-02-02 | 2016-02-29 | 4 | 0d |
| 6 |  | Identify and reserve locations | 5w | 2016-03-01 | 2016-04-04 | 5 | 0d |
| 7 |  | Book musicians | 2w | 2016-04-05 | 2016-04-18 | 6 | 0d |
| 8 |  | Book dancers | 2w | 2016-04-19 | 2016-05-02 | 7 | 0d |
| 9 |  | Reserve audio recording equipment | 1w | 2016-05-03 | 2016-05-09 | 8 | 0d |
| 10 |  | Reserve video recording equipment | 5d | 2016-05-10 | 2016-05-16 | 9 | 0d |
| 11 |  | Pre-Production complete | 0d | 2016-05-16 | 2016-05-16 | 10 | 0d |
| 12 | 2 | **Production** | 20.25d | 2016-05-16 | 2016-06-15 |  | 0d |
| 13 |  | Production begins | 0d | 2016-05-16 | 2016-05-16 | 11 | 0d |
| 14 | 2.2 | **Scene 1** | 6.75d | 2016-05-16 | 2016-05-25 |  | 0d |
| 15 |  | Scene 1 begin | 0d | 2016-05-16 | 2016-05-16 | 13 | 0d |
| 16 |  | Scene 1 setup | 2d | 2016-05-17 | 2016-05-18 | 15 | 0d |
| 17 |  | Scene 1 rehearsal | 6h | 2016-05-19 | 2016-05-19 | 16 | 0d |
| 18 |  | Scene 1 vocal recording | 1d | 2016-05-19 | 2016-05-20 | 17 | 0d |
| 19 |  | Scene 1 video shoot | 2d | 2016-05-20 | 2016-05-24 | 18 | 0d |
| 20 |  | Scene 1 teardown | 1d | 2016-05-24 | 2016-05-25 | 19 | 0d |
| 21 |  | Scene 1 complete | 0d | 2016-05-25 | 2016-05-25 | 20 | 0d |
| 22 | 2.3 | **Scene 2** | 6.75d | 2016-05-25 | 2016-06-06 |  | 0d |
| 23 |  | Scene 2 begin | 0d | 2016-05-25 | 2016-05-25 | 21 | 0d |
| 24 |  | Scene 2 setup | 2d | 2016-05-25 | 2016-05-27 | 23 | 0d |
| 25 |  | Scene 2 rehearsal | 6h | 2016-05-27 | 2016-05-31 | 24 | 0d |
| 26 |  | Scene 2 vocal recording | 1d | 2016-05-31 | 2016-06-01 | 25 | 0d |
| 27 |  | Scene 2 video shoot | 2d | 2016-06-01 | 2016-06-03 | 26 | 0d |
| 28 |  | Scene 2 teardown | 1d | 2016-06-03 | 2016-06-06 | 27 | 0d |
| 29 |  | Scene 2 complete | 0d | 2016-06-06 | 2016-06-06 | 28 | 0d |
| 30 | 2.4 | **Scene 3** | 6.75d | 2016-06-06 | 2016-06-15 |  | 0d |
| 31 |  | Scene 3 begin | 0d | 2016-06-06 | 2016-06-06 | 29 | 0d |
| 32 |  | Scene 3 setup | 2d | 2016-06-06 | 2016-06-08 | 31 | 0d |
| 33 |  | Scene 3 rehearsal | 6h | 2016-06-08 | 2016-06-09 | 32 | 0d |
| 34 |  | Scene 3 vocal recording | 1d | 2016-06-09 | 2016-06-10 | 33 | 0d |
| 35 |  | Scene 3 video shoot | 2d | 2016-06-10 | 2016-06-14 | 34 | 0d |
| 36 |  | Scene 3 teardown | 1d | 2016-06-14 | 2016-06-15 | 35 | 0d |
| 37 |  | Scene 3 complete | 0d | 2016-06-15 | 2016-06-15 | 36 | 0d |
| 38 |  | Production complete | 0d | 2016-06-15 | 2016-06-15 | 37 | 0d |
| 39 | 3 | **Post-Production** | 115.25d | 2016-01-04 | 2016-06-15 |  | 0d |
| 40 |  | Post-Production Begins | 0d | 2016-06-15 | 2016-06-15 | 38 | 0d |
| 41 |  | Post-Production complete | 0d | 2016-01-04 | 2016-01-04 |  | 115.25d |

## Version 2 (saved 2013-05-28, file donfunkmusicvideo3-5-mpp)

Last finish 2016-06-15 → 2016-06-01 (-14d).

Changed:

| ID | Task | Start | Finish | Duration | Other |
| --- | --- | --- | --- | --- | --- |
| 1 | **Pre-Production** |  | 2016-05-16 → 2016-05-02 (-14d) | 95d → 85d |  |
| 3 | Review screenplay |  | 2016-01-25 → 2016-01-26 (+1d) | 3w → 3.6w | resources none → Scott Seely; Jeff Pike |
| 4 | Develop scene blocking and schedule |  | 2016-02-01 → 2016-02-02 (+1d) | 1w → 1.2w | resources none → Scott Seely; Judy Lew |
| 5 | Develop production layouts |  | 2016-02-29 → 2016-02-15 (-14d) | 1mo → 0.5mo | resources none → Jeff Pike; Brenda Diaz; Annete Hill [50%]; Brad Sutton |
| 6 | Identify and reserve locations | 2016-03-01 → 2016-02-16 (-14d) | 2016-04-04 → 2016-03-21 (-14d) |  | resources none → Jeff Pike [57.1%]; Yan Li [57.1%]; Annete Hill [28.6%]; Ryan Ihrig [57.1%]; DVD [8 2-hour disc] |
| 7 | Book musicians | 2016-04-05 → 2016-03-22 (-14d) | 2016-04-18 → 2016-04-04 (-14d) |  | resources none → David Barber [50%]; Brenda Diaz [50%] |
| 8 | Book dancers | 2016-04-19 → 2016-04-05 (-14d) | 2016-05-02 → 2016-04-18 (-14d) |  |  |
| 9 | Reserve audio recording equipment | 2016-05-03 → 2016-04-19 (-14d) | 2016-05-09 → 2016-04-25 (-14d) |  |  |
| 10 | Reserve video recording equipment | 2016-05-10 → 2016-04-26 (-14d) | 2016-05-16 → 2016-05-02 (-14d) |  |  |
| 11 | Pre-Production complete | 2016-05-16 → 2016-05-02 (-14d) | 2016-05-16 → 2016-05-02 (-14d) |  |  |
| 12 | **Production** | 2016-05-16 → 2016-05-02 (-14d) | 2016-06-15 → 2016-06-01 (-14d) |  |  |
| 13 | Production begins | 2016-05-16 → 2016-05-02 (-14d) | 2016-05-16 → 2016-05-02 (-14d) |  |  |
| 14 | **Scene 1** | 2016-05-16 → 2016-05-02 (-14d) | 2016-05-25 → 2016-05-11 (-14d) |  |  |
| 15 | Scene 1 begin | 2016-05-16 → 2016-05-02 (-14d) | 2016-05-16 → 2016-05-02 (-14d) |  |  |
| 16 | Scene 1 setup | 2016-05-17 → 2016-05-03 (-14d) | 2016-05-18 → 2016-05-04 (-14d) |  |  |
| 17 | Scene 1 rehearsal | 2016-05-19 → 2016-05-05 (-14d) | 2016-05-19 → 2016-05-05 (-14d) |  | resources none → Food [0.1%] |
| 18 | Scene 1 vocal recording | 2016-05-19 → 2016-05-05 (-14d) | 2016-05-20 → 2016-05-06 (-14d) |  |  |
| 19 | Scene 1 video shoot | 2016-05-20 → 2016-05-06 (-14d) | 2016-05-24 → 2016-05-10 (-14d) |  |  |
| 20 | Scene 1 teardown | 2016-05-24 → 2016-05-10 (-14d) | 2016-05-25 → 2016-05-11 (-14d) |  |  |
| 21 | Scene 1 complete | 2016-05-25 → 2016-05-11 (-14d) | 2016-05-25 → 2016-05-11 (-14d) |  |  |
| 22 | **Scene 2** | 2016-05-25 → 2016-05-11 (-14d) | 2016-06-06 → 2016-05-20 (-17d) |  |  |
| 23 | Scene 2 begin | 2016-05-25 → 2016-05-11 (-14d) | 2016-05-25 → 2016-05-11 (-14d) |  |  |
| 24 | Scene 2 setup | 2016-05-25 → 2016-05-11 (-14d) | 2016-05-27 → 2016-05-13 (-14d) |  |  |
| 25 | Scene 2 rehearsal | 2016-05-27 → 2016-05-13 (-14d) | 2016-05-31 → 2016-05-16 (-15d) |  | resources none → Food [0.1%] |
| 26 | Scene 2 vocal recording | 2016-05-31 → 2016-05-16 (-15d) | 2016-06-01 → 2016-05-17 (-15d) |  |  |
| 27 | Scene 2 video shoot | 2016-06-01 → 2016-05-17 (-15d) | 2016-06-03 → 2016-05-19 (-15d) |  |  |
| 28 | Scene 2 teardown | 2016-06-03 → 2016-05-19 (-15d) | 2016-06-06 → 2016-05-20 (-17d) |  |  |
| 29 | Scene 2 complete | 2016-06-06 → 2016-05-20 (-17d) | 2016-06-06 → 2016-05-20 (-17d) |  |  |
| 30 | **Scene 3** | 2016-06-06 → 2016-05-20 (-17d) | 2016-06-15 → 2016-06-01 (-14d) |  |  |
| 31 | Scene 3 begin | 2016-06-06 → 2016-05-20 (-17d) | 2016-06-06 → 2016-05-20 (-17d) |  |  |
| 32 | Scene 3 setup | 2016-06-06 → 2016-05-20 (-17d) | 2016-06-08 → 2016-05-24 (-15d) |  |  |
| 33 | Scene 3 rehearsal | 2016-06-08 → 2016-05-24 (-15d) | 2016-06-09 → 2016-05-25 (-15d) |  |  |
| 34 | Scene 3 vocal recording | 2016-06-09 → 2016-05-25 (-15d) | 2016-06-10 → 2016-05-26 (-15d) |  |  |
| 35 | Scene 3 video shoot | 2016-06-10 → 2016-05-26 (-15d) | 2016-06-14 → 2016-05-31 (-14d) |  |  |
| 36 | Scene 3 teardown | 2016-06-14 → 2016-05-31 (-14d) | 2016-06-15 → 2016-06-01 (-14d) |  |  |
| 37 | Scene 3 complete | 2016-06-15 → 2016-06-01 (-14d) | 2016-06-15 → 2016-06-01 (-14d) |  |  |
| 38 | Production complete | 2016-06-15 → 2016-06-01 (-14d) | 2016-06-15 → 2016-06-01 (-14d) |  |  |
| 39 | **Post-Production** |  | 2016-06-15 → 2016-06-01 (-14d) | 115.25d → 105.25d |  |
| 40 | Post-Production Begins | 2016-06-15 → 2016-06-01 (-14d) | 2016-06-15 → 2016-06-01 (-14d) |  |  |

## Version 3 (saved 2013-05-28, file donfunkmusicvideo4-4-mpp)

Last finish 2016-06-01 → 2016-07-29 (+58d).

Added:

| ID | Task | Duration | Start | Finish | Predecessors | Constraint | Resources |
| --- | --- | --- | --- | --- | --- | --- | --- |
| 11 | **Status Meeting** | 69.12d | 2016-01-04 | 2016-04-11 |  |  |  |
| 12 | Status Meeting 1 | 1h | 2016-01-04 | 2016-01-04 |  | start no earlier than 2016-01-04 | Brad Sutton; Chris Preston; Eva Corets; Jamie Reding; Jane Clayton; Judy Lew |
| 13 | Status Meeting 2 | 1h | 2016-01-11 | 2016-01-11 |  | start no earlier than 2016-01-11 | Brad Sutton; Chris Preston; Eva Corets; Jamie Reding; Jane Clayton; Judy Lew |
| 14 | Status Meeting 3 | 1h | 2016-01-19 | 2016-01-19 |  | start no earlier than 2016-01-18 | Brad Sutton; Chris Preston; Eva Corets; Jamie Reding; Jane Clayton; Judy Lew |
| 15 | Status Meeting 4 | 1h | 2016-01-25 | 2016-01-25 |  | start no earlier than 2016-01-25 | Brad Sutton; Chris Preston; Eva Corets; Jamie Reding; Jane Clayton; Judy Lew |
| 16 | Status Meeting 5 | 1h | 2016-02-01 | 2016-02-01 |  | start no earlier than 2016-02-01 | Brad Sutton; Chris Preston; Eva Corets; Jamie Reding; Jane Clayton; Judy Lew |
| 17 | Status Meeting 6 | 1h | 2016-02-08 | 2016-02-08 |  | start no earlier than 2016-02-08 | Brad Sutton; Chris Preston; Eva Corets; Jamie Reding; Jane Clayton; Judy Lew |
| 18 | Status Meeting 7 | 1h | 2016-02-15 | 2016-02-15 |  | start no earlier than 2016-02-15 | Brad Sutton; Chris Preston; Eva Corets; Jamie Reding; Jane Clayton; Judy Lew |
| 19 | Status Meeting 8 | 1h | 2016-02-22 | 2016-02-22 |  | start no earlier than 2016-02-22 | Brad Sutton; Chris Preston; Eva Corets; Jamie Reding; Jane Clayton; Judy Lew |
| 20 | Status Meeting 9 | 1h | 2016-02-29 | 2016-02-29 |  | start no earlier than 2016-02-29 | Brad Sutton; Chris Preston; Eva Corets; Jamie Reding; Jane Clayton; Judy Lew |
| 21 | Status Meeting 10 | 1h | 2016-03-07 | 2016-03-07 |  | start no earlier than 2016-03-07 | Brad Sutton; Chris Preston; Eva Corets; Jamie Reding; Jane Clayton; Judy Lew |
| 22 | Status Meeting 11 | 1h | 2016-03-14 | 2016-03-14 |  | start no earlier than 2016-03-14 | Brad Sutton; Chris Preston; Eva Corets; Jamie Reding; Jane Clayton; Judy Lew |
| 23 | Status Meeting 12 | 1h | 2016-03-21 | 2016-03-21 |  | start no earlier than 2016-03-21 | Brad Sutton; Chris Preston; Eva Corets; Jamie Reding; Jane Clayton; Judy Lew |
| 24 | Status Meeting 13 | 1h | 2016-03-28 | 2016-03-28 |  | start no earlier than 2016-03-28 | Brad Sutton; Chris Preston; Eva Corets; Jamie Reding; Jane Clayton; Judy Lew |
| 25 | Status Meeting 14 | 1h | 2016-04-04 | 2016-04-04 |  | start no earlier than 2016-04-04 | Brad Sutton; Chris Preston; Eva Corets; Jamie Reding; Jane Clayton; Judy Lew |
| 26 | Status Meeting 15 | 1h | 2016-04-11 | 2016-04-11 |  | start no earlier than 2016-04-11 | Brad Sutton; Chris Preston; Eva Corets; Jamie Reding; Jane Clayton; Judy Lew |
| 54 | **Scene 4** | 6.75d | 2016-06-14 | 2016-06-23 |  |  |  |
| 55 | Scene 4 begin | 0d | 2016-06-14 | 2016-06-14 | 53 |  |  |
| 56 | Scene 4 setup | 2d | 2016-06-15 | 2016-06-16 | 55 |  | Brad Sutton; Chris Preston; electrician |
| 57 | Scene 4 rehearsal | 6h | 2016-06-17 | 2016-06-17 | 56 |  | dancers; musician |
| 58 | Scene 4 vocal recording | 1d | 2016-06-17 | 2016-06-20 | 57 |  | musician; Sound Technician; Don Funk; Luis Bonifaz |
| 59 | Scene 4 video shoot | 2d | 2016-06-20 | 2016-06-22 | 58 |  | Sound Technician; DVD [1 2-hour disc]; Don Funk; David Barber [50%]; Dry Ice [1 10 lb block]; Frank Zhang [50%]; Bottled Water [1 24 bottle case] |
| 60 | Scene 4 teardown | 1d | 2016-06-22 | 2016-06-23 | 59 |  | Patricia Doyle; Ido Ben-Sachar |
| 61 | Scene 4 complete | 0d | 2016-06-23 | 2016-06-23 | 60 |  |  |
| 65 | Log video footage | 3d | 2016-06-23 | 2016-06-28 | 64 |  | Video Editing Studio; Shu Ito |
| 66 | Log audio tracks by scene | 2d | 2016-06-23 | 2016-06-27 | 64 |  | Sound Editing Studio; Maria Hammond; Jim Kim |
| 67 | Rough edit video - paper | 1w | 2016-06-28 | 2016-07-05 | 65, 66 |  | Bjorn Rettig [50%]; Florian Voss; Jamie Reding; Jane Clayton; Shu Ito |
| 68 | Rough audio edit | 1w | 2016-07-05 | 2016-07-12 | 67 |  |  |
| 69 | Fine audio edit | 3d | 2016-07-12 | 2016-07-15 | 68 |  | Sound Editing Studio; Maria Hammond; Jim Kim |
| 70 | Fine video edit | 3d | 2016-07-12 | 2016-07-15 | 68 |  | Video Editing Studio; Shu Ito; Greg Guzik; David Barber [50%] |
| 71 | Dub audio to video | 2d | 2016-07-15 | 2016-07-19 | 70 |  | Video Editing Studio; Shu Ito |
| 72 | Internal review viewing | 1d | 2016-07-19 | 2016-07-20 | 71 |  | Scott Seely; Jamie Reding; Jeff Pike; Judy Lew; Brad Sutton; Brenda Diaz; Annette Hill [50%]; Don Funk; Ryan Ihrig |
| 73 | Final edits | 4d | 2016-07-20 | 2016-07-25 | 72 |  | Jamie Reding; Scott Seely; Jeff Pike; Brad Sutton; Annette Hill [50%]; Video Editing Studio |
| 74 | Formal approval viewing | 1d | 2016-07-25 | 2016-07-26 | 73 |  | Scott Seely; Judy Lew; Brad Sutton; Don Funk; Annette Hill [50%]; Jane Clayton; Video Editing Studio |
| 75 | Duplicate audio and video masters | 1d | 2016-07-26 | 2016-07-27 | 74 |  | Sound Technician; Sound Editing Studio; Video Editing Studio; Shu Ito; Patricia Doyle; Luis Bonifaz |
| 76 | Archive Copy 1 AV masters | 1d | 2016-07-27 | 2016-07-28 | 75 |  | Yan Li |
| 77 | Send Copy 2 AV master and dubbed master to | 1d | 2016-07-28 | 2016-07-29 | 76 |  | Yan Li |

Changed:

| ID | Task | Start | Finish | Duration | Total float | Predecessors | Other |
| --- | --- | --- | --- | --- | --- | --- | --- |
| 1 | **Pre-Production** |  | 2016-05-02 → 2016-05-11 (+9d) | 85d → 91.38d | 0d → 2.88d |  |  |
| 4 | Develop scene blocking and schedule |  | 2016-02-02 → 2016-02-05 (+3d) | 1.2w → 2w | 0d → 2.88d |  | resources Scott Seely; Judy Lew → Scott Seely [58%]; Judy Lew [59.7%] |
| 5 | Develop production layouts | 2016-02-02 → 2016-02-05 (+3d) | 2016-02-15 → 2016-02-24 (+9d) |  | 0d → 0.38d |  |  |
| 6 | Identify and reserve locations | 2016-02-16 → 2016-02-24 (+8d) | 2016-03-21 → 2016-03-30 (+9d) |  | 0d → 0.38d |  | resources Jeff Pike [57.1%]; Yan Li [57.1%]; Annete Hill [28.6%]; Ryan Ihrig [57.1%]; DVD [8 2-hour disc] → Jeff Pike [50%]; Yan Li [57.1%]; Annete Hill [28.6%]; Ryan Ihrig [75%]; DVD [8 2-hour disc] |
| 7 | Book musicians | 2016-03-22 → 2016-03-30 (+8d) | 2016-04-04 → 2016-04-13 (+9d) |  | 0d → 0.38d |  | resources David Barber [50%]; Brenda Diaz [50%] → none |
| 8 | Book dancers | 2016-04-05 → 2016-04-13 (+8d) | 2016-04-18 → 2016-04-27 (+9d) |  | 0d → 0.38d |  |  |
| 9 | Reserve audio recording equipment | 2016-04-19 → 2016-04-27 (+8d) | 2016-04-25 → 2016-05-04 (+9d) |  | 0d → 0.38d |  |  |
| 10 | Reserve video recording equipment | 2016-04-26 → 2016-05-04 (+8d) | 2016-05-02 → 2016-05-11 (+9d) |  | 0d → 0.38d |  |  |
| 27 | Pre-Production complete | 2016-05-02 → 2016-05-11 (+9d) | 2016-05-02 → 2016-05-11 (+9d) |  | 0d → 0.38d |  |  |
| 28 | **Production** | 2016-05-02 → 2016-05-11 (+9d) | 2016-06-01 → 2016-06-23 (+22d) | 20.25d → 30.38d |  |  |  |
| 29 | Production begins | 2016-05-02 → 2016-05-11 (+9d) | 2016-05-02 → 2016-05-11 (+9d) |  | 0d → 0.38d |  |  |
| 30 | **Scene 1** | 2016-05-02 → 2016-05-11 (+9d) | 2016-05-11 → 2016-05-20 (+9d) |  | 0d → 3.38d |  |  |
| 31 | Scene 1 begin | 2016-05-02 → 2016-05-11 (+9d) | 2016-05-02 → 2016-05-11 (+9d) |  | 0d → 0.38d |  |  |
| 32 | Scene 1 setup | 2016-05-03 → 2016-05-11 (+8d) | 2016-05-04 → 2016-05-13 (+9d) |  | 0d → 0.38d |  | resources none → Light Banks; Chris Preston; Brad Sutton |
| 33 | Scene 1 rehearsal | 2016-05-05 → 2016-05-13 (+8d) | 2016-05-05 → 2016-05-16 (+11d) |  | 0d → 0.38d |  | resources Food [0.1%] → Food [0.1%]; Frank Zhang [50%]; Jim Kim; dancers; musician |
| 34 | Scene 1 vocal recording | 2016-05-05 → 2016-05-16 (+11d) | 2016-05-06 → 2016-05-17 (+11d) |  | 0d → 0.38d |  | resources none → Food [0.1%]; Jeff Pike; Don Funk; Sound Technician; musician |
| 35 | Scene 1 video shoot | 2016-05-06 → 2016-05-17 (+11d) | 2016-05-10 → 2016-05-19 (+9d) |  | 0d → 0.38d |  | resources none → Sound Technician; Microphone Bundles; Don Funk; DVD [1 2-hour disc]; David Barber [50%]; Greg Guzik; Bottled Water [1 24 bottle case] |
| 36 | Scene 1 teardown | 2016-05-10 → 2016-05-19 (+9d) | 2016-05-11 → 2016-05-20 (+9d) |  | 0d → 0.38d |  | resources none → Ido Ben-Sachar; Patricia Doyle |
| 37 | Scene 1 complete | 2016-05-11 → 2016-05-20 (+9d) | 2016-05-11 → 2016-05-20 (+9d) |  | 0d → 0.38d |  |  |
| 38 | **Scene 2** | 2016-05-11 → 2016-05-25 (+14d) | 2016-05-20 → 2016-06-03 (+14d) |  | 0d → 0.5d |  |  |
| 39 | Scene 2 begin | 2016-05-11 → 2016-05-25 (+14d) | 2016-05-11 → 2016-05-25 (+14d) |  | 0d → 0.5d |  | constraint none → start no earlier than 2016-05-25 |
| 40 | Scene 2 setup | 2016-05-11 → 2016-05-25 (+14d) | 2016-05-13 → 2016-05-26 (+13d) |  | 0d → 0.5d |  | resources none → Brad Sutton; Dolly; Chris Preston; electrician |
| 41 | Scene 2 rehearsal | 2016-05-13 → 2016-05-27 (+14d) | 2016-05-16 → 2016-05-27 (+11d) |  | 0d → 0.5d |  | resources Food [0.1%] → Food [0.1%]; Luis Bonifaz; dancers; musician |
| 42 | Scene 2 vocal recording | 2016-05-16 → 2016-05-27 (+11d) | 2016-05-17 → 2016-05-31 (+14d) |  | 0d → 0.5d |  | resources none → Yan Li; Sound Technician; Don Funk; musician |
| 43 | Scene 2 video shoot | 2016-05-17 → 2016-05-31 (+14d) | 2016-05-19 → 2016-06-02 (+14d) |  | 0d → 0.5d |  | resources none → Digital Truck-Mounted Video Camera; Dolly; Don Funk; DVD [1 2-hour disc]; dancers; Bottled Water [1 24 bottle case]; Jane Clayton; musician |
| 44 | Scene 2 teardown | 2016-05-19 → 2016-06-02 (+14d) | 2016-05-20 → 2016-06-03 (+14d) |  | 0d → 0.5d |  | resources none → Ido Ben-Sachar; Patricia Doyle |
| 45 | Scene 2 complete | 2016-05-20 → 2016-06-03 (+14d) | 2016-05-20 → 2016-06-03 (+14d) |  | 0d → 0.5d |  |  |
| 46 | **Scene 3** | 2016-05-20 → 2016-06-03 (+14d) | 2016-06-01 → 2016-06-14 (+13d) | 6.75d → 7.25d |  |  |  |
| 47 | Scene 3 begin | 2016-05-20 → 2016-06-03 (+14d) | 2016-05-20 → 2016-06-03 (+14d) |  | 0d → 0.5d |  |  |
| 48 | Scene 3 setup | 2016-05-20 → 2016-06-03 (+14d) | 2016-05-24 → 2016-06-07 (+14d) |  | 0d → 0.5d |  | resources none → Brad Sutton; Chris Preston |
| 49 | Scene 3 rehearsal | 2016-05-24 → 2016-06-07 (+14d) | 2016-05-25 → 2016-06-08 (+14d) |  | 0d → 0.5d |  | resources none → dancers; Eva Corets; musician |
| 50 | Scene 3 vocal recording | 2016-05-25 → 2016-06-08 (+14d) | 2016-05-26 → 2016-06-09 (+14d) |  | 0d → 0.5d |  | resources none → musician; Sound Technician; Don Funk |
| 51 | Scene 3 video shoot | 2016-05-26 → 2016-06-09 (+14d) | 2016-05-31 → 2016-06-14 (+14d) |  | 0d → 0.25d |  | resources none → Bottled Water [1 24 bottle case]; dancers; DVD [1 2-hour disc]; Dry Ice [1 10 lb block]; Don Funk; Florian Voss |
| 52 | Scene 3 teardown | 2016-05-31 → 2016-06-14 (+14d) | 2016-06-01 → 2016-06-14 (+13d) |  |  |  | resources none → Ido Ben-Sachar; Patricia Doyle |
| 53 | Scene 3 complete | 2016-06-01 → 2016-06-14 (+13d) | 2016-06-01 → 2016-06-14 (+13d) |  |  |  |  |
| 62 | Production complete | 2016-06-01 → 2016-06-23 (+22d) | 2016-06-01 → 2016-06-23 (+22d) |  |  | 53 → 61 |  |
| 63 | **Post-Production** | 2016-01-04 → 2016-06-23 (+171d) | 2016-06-01 → 2016-07-29 (+58d) | 105.25d → 26d |  |  |  |
| 64 | Post-Production Begins | 2016-06-01 → 2016-06-23 (+22d) | 2016-06-01 → 2016-06-23 (+22d) |  |  |  |  |
| 78 | Post-Production complete | 2016-01-04 → 2016-07-29 (+207d) | 2016-01-04 → 2016-07-29 (+207d) |  | 115.25d → 0d | none → 77 |  |

## Version 4 (saved 2013-05-28, file donfunkmusicvideo5-6-mpp)

Last finish stays 2016-07-29.

Changed:

| ID | Task | Start | Finish | Duration | Total float | Other |
| --- | --- | --- | --- | --- | --- | --- |
| 1 | **Pre-Production** |  | 2016-05-11 → 2016-05-05 (-6d) | 91.38d → 88d | 2.88d → -4d |  |
| 4 | Develop scene blocking and schedule | 2016-01-26 → 2016-01-20 (-6d) | 2016-02-05 → 2016-02-01 (-4d) | 2w → 2.12w | 2.88d → -4d | constraint none → start no later than 2016-01-20 |
| 5 | Develop production layouts | 2016-02-05 → 2016-02-02 (-3d) | 2016-02-24 → 2016-02-18 (-6d) |  | 0.38d → 6.75d |  |
| 6 | Identify and reserve locations | 2016-02-24 → 2016-02-19 (-5d) | 2016-03-30 → 2016-03-24 (-6d) |  | 0.38d → 4d |  |
| 7 | Book musicians | 2016-03-30 → 2016-03-25 (-5d) | 2016-04-13 → 2016-04-07 (-6d) |  | 0.38d → 4d |  |
| 8 | Book dancers | 2016-04-13 → 2016-04-08 (-5d) | 2016-04-27 → 2016-04-21 (-6d) |  | 0.38d → 4d |  |
| 9 | Reserve audio recording equipment | 2016-04-27 → 2016-04-22 (-5d) | 2016-05-04 → 2016-04-28 (-6d) |  | 0.38d → 6.75d |  |
| 10 | Reserve video recording equipment | 2016-05-04 → 2016-04-29 (-5d) | 2016-05-11 → 2016-05-05 (-6d) |  | 0.38d → 4d |  |
| 27 | Pre-Production complete | 2016-05-11 → 2016-05-05 (-6d) | 2016-05-11 → 2016-05-05 (-6d) |  | 0.38d → 6.75d |  |
| 28 | **Production** | 2016-05-11 → 2016-05-05 (-6d) |  | 30.38d → 33.75d |  |  |
| 29 | Production begins | 2016-05-11 → 2016-05-05 (-6d) | 2016-05-11 → 2016-05-05 (-6d) |  | 0.38d → 6.75d |  |
| 30 | **Scene 1** | 2016-05-11 → 2016-05-05 (-6d) | 2016-05-20 → 2016-05-16 (-4d) |  | 3.38d → 6.75d |  |
| 31 | Scene 1 begin | 2016-05-11 → 2016-05-05 (-6d) | 2016-05-11 → 2016-05-05 (-6d) |  | 0.38d → 6.75d |  |
| 32 | Scene 1 setup | 2016-05-11 → 2016-05-06 (-5d) | 2016-05-13 → 2016-05-09 (-4d) |  | 0.38d → 6.75d |  |
| 33 | Scene 1 rehearsal | 2016-05-13 → 2016-05-10 (-3d) | 2016-05-16 → 2016-05-10 (-6d) |  | 0.38d → 6.75d |  |
| 34 | Scene 1 vocal recording | 2016-05-16 → 2016-05-10 (-6d) | 2016-05-17 → 2016-05-11 (-6d) |  | 0.38d → 6.75d |  |
| 35 | Scene 1 video shoot | 2016-05-17 → 2016-05-11 (-6d) | 2016-05-19 → 2016-05-13 (-6d) |  | 0.38d → 6.75d |  |
| 36 | Scene 1 teardown | 2016-05-19 → 2016-05-13 (-6d) | 2016-05-20 → 2016-05-16 (-4d) |  | 0.38d → 6.75d |  |
| 37 | Scene 1 complete | 2016-05-20 → 2016-05-16 (-4d) | 2016-05-20 → 2016-05-16 (-4d) |  | 0.38d → 6.75d |  |

## Version 5 (saved 2013-05-28, file donfunkmusicvideo6-6-mpp)

Last finish 2016-07-29 → 2016-08-03 (+5d).

Changed:

| ID | Task | Start | Finish | Duration | Total float | Other |
| --- | --- | --- | --- | --- | --- | --- |
| 1 | **Pre-Production** |  | 2016-05-05 → 2016-05-11 (+6d) | 88d → 91.75d | -4d → 0d |  |
| 4 | Develop scene blocking and schedule | 2016-01-20 → 2016-01-26 (+6d) | 2016-02-01 → 2016-02-05 (+4d) | 2.12w → 2w | -4d → 0d | constraint start no later than 2016-01-20 → none |
| 5 | Develop production layouts | 2016-02-02 → 2016-02-05 (+3d) | 2016-02-18 → 2016-02-24 (+6d) | 0.5mo → 0.53mo | 6.75d → 0.25d |  |
| 6 | Identify and reserve locations | 2016-02-19 → 2016-02-24 (+5d) | 2016-03-24 → 2016-03-30 (+6d) |  | 4d → 0.25d |  |
| 7 | Book musicians | 2016-03-25 → 2016-03-30 (+5d) | 2016-04-07 → 2016-04-13 (+6d) |  | 4d → 0.25d |  |
| 8 | Book dancers | 2016-04-08 → 2016-04-13 (+5d) | 2016-04-21 → 2016-04-27 (+6d) |  | 4d → 0.25d |  |
| 9 | Reserve audio recording equipment | 2016-04-22 → 2016-04-27 (+5d) | 2016-04-28 → 2016-05-04 (+6d) |  | 6.75d → 0.25d |  |
| 10 | Reserve video recording equipment | 2016-04-29 → 2016-05-04 (+5d) | 2016-05-05 → 2016-05-11 (+6d) |  | 4d → 0.25d |  |
| 27 | Pre-Production complete | 2016-05-05 → 2016-05-11 (+6d) | 2016-05-05 → 2016-05-11 (+6d) |  | 6.75d → 0.25d |  |
| 28 | **Production** | 2016-05-05 → 2016-05-11 (+6d) |  | 33.75d → 30d |  |  |
| 29 | Production begins | 2016-05-05 → 2016-05-11 (+6d) | 2016-05-05 → 2016-05-11 (+6d) |  | 6.75d → 3d |  |
| 30 | **Scene 1** | 2016-05-05 → 2016-05-11 (+6d) | 2016-05-16 → 2016-05-20 (+4d) |  | 6.75d → 3d |  |
| 31 | Scene 1 begin | 2016-05-05 → 2016-05-11 (+6d) | 2016-05-05 → 2016-05-11 (+6d) |  | 6.75d → 3d |  |
| 32 | Scene 1 setup | 2016-05-06 → 2016-05-11 (+5d) | 2016-05-09 → 2016-05-13 (+4d) |  | 6.75d → 3d |  |
| 33 | Scene 1 rehearsal | 2016-05-10 → 2016-05-13 (+3d) | 2016-05-10 → 2016-05-16 (+6d) |  | 6.75d → 3d |  |
| 34 | Scene 1 vocal recording | 2016-05-10 → 2016-05-16 (+6d) | 2016-05-11 → 2016-05-17 (+6d) |  | 6.75d → 3d |  |
| 35 | Scene 1 video shoot | 2016-05-11 → 2016-05-17 (+6d) | 2016-05-13 → 2016-05-19 (+6d) |  | 6.75d → 3d | resources Sound Technician; Microphone Bundles; Don Funk; DVD [1 2-hour disc]; David Barber [50%]; Greg Guzik; Bottled Water [1 24 bottle case] → Sound Technician; Microphone Bundles; Don Funk; DVD [0.25 2-hour disc]; David Barber [50%]; Greg Guzik; Bottled Water [1 24 bottle case] |
| 36 | Scene 1 teardown | 2016-05-13 → 2016-05-19 (+6d) | 2016-05-16 → 2016-05-20 (+4d) |  | 6.75d → 3d |  |
| 37 | Scene 1 complete | 2016-05-16 → 2016-05-20 (+4d) | 2016-05-16 → 2016-05-20 (+4d) |  | 6.75d → 3d |  |
| 63 | **Post-Production** |  | 2016-07-29 → 2016-08-03 (+5d) | 26d → 29.25d |  |  |
| 65 | Log video footage |  |  |  | 0d → 1.75d | resources Video Editing Studio; Shu Ito → Video Editing Studio; Shu Ito; Jim Kim |
| 66 | Log audio tracks by scene |  | 2016-06-27 → 2016-06-30 (+3d) | 2d → 3.75d | 1d → 0d |  |
| 67 | Rough edit video - paper | 2016-06-28 → 2016-06-30 (+2d) | 2016-07-05 → 2016-07-07 (+2d) |  |  |  |
| 68 | Rough audio edit | 2016-07-05 → 2016-07-07 (+2d) | 2016-07-12 → 2016-07-14 (+2d) |  |  |  |
| 69 | Fine audio edit | 2016-07-12 → 2016-07-14 (+2d) | 2016-07-15 → 2016-07-19 (+4d) |  | 10d → 11.5d | resources Sound Editing Studio; Maria Hammond; Jim Kim → Sound Editing Studio; Maria Hammond; Jim Kim; Greg Guzik [50%] |
| 70 | Fine video edit | 2016-07-12 → 2016-07-14 (+2d) | 2016-07-15 → 2016-07-19 (+4d) |  |  | resources Video Editing Studio; Shu Ito; Greg Guzik; David Barber [50%] → Video Editing Studio; Shu Ito; Greg Guzik [50%]; David Barber [50%] |
| 71 | Dub audio to video | 2016-07-15 → 2016-07-19 (+4d) | 2016-07-19 → 2016-07-21 (+2d) |  |  |  |
| 72 | Internal review viewing | 2016-07-19 → 2016-07-21 (+2d) | 2016-07-20 → 2016-07-25 (+5d) | 1d → 1.25d |  | resources Scott Seely; Jamie Reding; Jeff Pike; Judy Lew; Brad Sutton; Brenda Diaz; Annette Hill [50%]; Don Funk; Ryan Ihrig → Scott Seely; Jamie Reding; Jeff Pike; Judy Lew; Brad Sutton; Brenda Diaz; Don Funk; Ryan Ihrig |
| 73 | Final edits | 2016-07-20 → 2016-07-25 (+5d) | 2016-07-25 → 2016-07-28 (+3d) | 4d → 3.5d |  | resources Jamie Reding; Scott Seely; Jeff Pike; Brad Sutton; Annette Hill [50%]; Video Editing Studio → Jamie Reding; Scott Seely; Jeff Pike; Brad Sutton; Video Editing Studio |
| 74 | Formal approval viewing | 2016-07-25 → 2016-07-28 (+3d) | 2016-07-26 → 2016-08-01 (+6d) |  |  | resources Scott Seely; Judy Lew; Brad Sutton; Don Funk; Annette Hill [50%]; Jane Clayton; Video Editing Studio → Scott Seely; Judy Lew; Brad Sutton; Don Funk; Jane Clayton; Video Editing Studio |
| 75 | Duplicate audio and video masters | 2016-07-26 → 2016-08-01 (+6d) | 2016-07-27 → 2016-08-01 (+5d) |  |  |  |
| 76 | Archive Copy 1 AV masters | 2016-07-27 → 2016-08-02 (+6d) | 2016-07-28 → 2016-08-02 (+5d) |  |  |  |
| 77 | Send Copy 2 AV master and dubbed master to | 2016-07-28 → 2016-08-03 (+6d) | 2016-07-29 → 2016-08-03 (+5d) |  |  |  |
| 78 | Post-Production complete | 2016-07-29 → 2016-08-03 (+5d) | 2016-07-29 → 2016-08-03 (+5d) |  |  |  |

## Version 6 (saved 2013-05-28, file donfunkmusicvideo8-5-mpp)

Last finish 2016-08-03 → 2016-07-29 (-5d).

Changed:

| ID | Task | Start | Finish | Duration | Total float | Other |
| --- | --- | --- | --- | --- | --- | --- |
| 63 | **Post-Production** |  | 2016-08-03 → 2016-07-29 (-5d) | 29.25d → 26d |  |  |
| 66 | Log audio tracks by scene |  | 2016-06-30 → 2016-06-28 (-2d) | 3.75d → 3d |  | resources Sound Editing Studio; Maria Hammond; Jim Kim → Sound Editing Studio; Maria Hammond; David Barber |
| 67 | Rough edit video - paper | 2016-06-30 → 2016-06-28 (-2d) | 2016-07-07 → 2016-07-05 (-2d) |  |  |  |
| 68 | Rough audio edit | 2016-07-07 → 2016-07-05 (-2d) | 2016-07-14 → 2016-07-12 (-2d) |  |  |  |
| 69 | Fine audio edit | 2016-07-14 → 2016-07-12 (-2d) | 2016-07-19 → 2016-07-15 (-4d) |  | 11.5d → 10d |  |
| 70 | Fine video edit | 2016-07-14 → 2016-07-12 (-2d) | 2016-07-19 → 2016-07-15 (-4d) |  |  |  |
| 71 | Dub audio to video | 2016-07-19 → 2016-07-15 (-4d) | 2016-07-21 → 2016-07-19 (-2d) |  |  |  |
| 72 | Internal review viewing | 2016-07-21 → 2016-07-19 (-2d) | 2016-07-25 → 2016-07-20 (-5d) | 1.25d → 1d |  |  |
| 73 | Final edits | 2016-07-25 → 2016-07-20 (-5d) | 2016-07-28 → 2016-07-25 (-3d) | 3.5d → 4d |  |  |
| 74 | Formal approval viewing | 2016-07-28 → 2016-07-25 (-3d) | 2016-08-01 → 2016-07-26 (-6d) |  |  |  |
| 75 | Duplicate audio and video masters | 2016-08-01 → 2016-07-26 (-6d) | 2016-08-01 → 2016-07-27 (-5d) |  |  |  |
| 76 | Archive Copy 1 AV masters | 2016-08-02 → 2016-07-27 (-6d) | 2016-08-02 → 2016-07-28 (-5d) |  |  |  |
| 77 | Send Copy 2 AV master and dubbed master to | 2016-08-03 → 2016-07-28 (-6d) | 2016-08-03 → 2016-07-29 (-5d) |  |  |  |
| 78 | Post-Production complete | 2016-08-03 → 2016-07-29 (-5d) | 2016-08-03 → 2016-07-29 (-5d) |  |  |  |

## Version 7 (data date 2016-02-12, saved 2013-06-29, file donfunkmusicvideo9-6-mpp)

Last finish 2016-07-29 → 2016-08-04 (+6d). Complete tasks 0 → 47.

Changed:

| ID | Task | Start | Finish | Duration | Complete | Total float | Other |
| --- | --- | --- | --- | --- | --- | --- | --- |
| 1 | **Pre-Production** | 2016-01-04 A | 2016-05-11 → 2016-05-09 A (-2d) | 91.75d → 89.25d | 0% → 100% | 0d → none | baseline start none → 2016-01-04; baseline finish none → 2016-05-11 |
| 2 | Pre-Production begins | 2016-01-04 A | 2016-01-04 A |  | 0% → 100% | 0d → none | baseline start none → 2016-01-04; baseline finish none → 2016-01-04 |
| 3 | Review screenplay | 2016-01-04 A | 2016-01-26 A |  | 0% → 100% | 0d → none | baseline start none → 2016-01-04; baseline finish none → 2016-01-26 |
| 4 | Develop scene blocking and schedule | 2016-01-26 A | 2016-02-05 → 2016-02-04 A (-1d) | 2w → 9.62d | 0% → 100% | 0d → none | baseline start none → 2016-01-26; baseline finish none → 2016-02-05 |
| 5 | Develop production layouts | 2016-02-05 A | 2016-02-24 A |  | 0% → 100% | 0.25d → none | baseline start none → 2016-02-05; baseline finish none → 2016-02-24 |
| 6 | Identify and reserve locations | 2016-02-24 A | 2016-03-30 → 2016-03-28 A (-2d) | 5w → 22.5d | 0% → 100% | 0.25d → none | resources Jeff Pike [50%]; Yan Li [57.1%]; Annete Hill [28.6%]; Ryan Ihrig [75%]; DVD [8 2-hour disc] → Jeff Pike [50%]; Yan Li [57.1%]; Annete Hill [28.6%]; Ryan Ihrig [75%]; DVD [7.2 2-hour disc]; baseline start none → 2016-02-24; baseline finish none → 2016-03-30 |
| 7 | Book musicians | 2016-03-30 → 2016-03-28 A (-2d) | 2016-04-13 → 2016-04-11 A (-2d) |  | 0% → 100% | 0.25d → none | resources none → Annette Hill [50%]; David Barber [50%]; baseline start none → 2016-03-28; baseline finish none → 2016-04-11 |
| 8 | Book dancers | 2016-04-13 → 2016-04-11 A (-2d) | 2016-04-27 → 2016-04-25 A (-2d) |  | 0% → 100% | 0.25d → none | resources none → Annette Hill [50%]; David Barber [50%]; baseline start none → 2016-04-11; baseline finish none → 2016-04-25 |
| 9 | Reserve audio recording equipment | 2016-04-27 → 2016-04-25 A (-2d) | 2016-05-04 → 2016-05-02 A (-2d) |  | 0% → 100% | 0.25d → none | resources none → Yan Li; Sound Technician; baseline start none → 2016-04-25; baseline finish none → 2016-05-02 |
| 10 | Reserve video recording equipment | 2016-05-04 → 2016-05-02 A (-2d) | 2016-05-11 → 2016-05-09 A (-2d) |  | 0% → 100% | 0.25d → none | resources none → Sound Technician; Yan Li; baseline start none → 2016-05-02; baseline finish none → 2016-05-09 |
| 11 | **Status Meeting** | 2016-01-04 A | 2016-04-11 A |  | 0% → 100% | 78.62d → none | baseline start none → 2016-01-04; baseline finish none → 2016-04-11 |
| 12 | Status Meeting 1 | 2016-01-04 A | 2016-01-04 A |  | 0% → 100% | 147.62d → none | baseline start none → 2016-01-04; baseline finish none → 2016-01-04 |
| 13 | Status Meeting 2 | 2016-01-11 A | 2016-01-11 A |  | 0% → 100% | 142.62d → none | baseline start none → 2016-01-11; baseline finish none → 2016-01-11 |
| 14 | Status Meeting 3 | 2016-01-19 A | 2016-01-19 A |  | 0% → 100% | 137.62d → none | baseline start none → 2016-01-19; baseline finish none → 2016-01-19 |
| 15 | Status Meeting 4 | 2016-01-25 A | 2016-01-25 A |  | 0% → 100% | 133.62d → none | baseline start none → 2016-01-25; baseline finish none → 2016-01-25 |
| 16 | Status Meeting 5 | 2016-02-01 A | 2016-02-01 A |  | 0% → 100% | 128.62d → none | baseline start none → 2016-02-01; baseline finish none → 2016-02-01 |
| 17 | Status Meeting 6 | 2016-02-08 A | 2016-02-08 A |  | 0% → 100% | 123.62d → none | baseline start none → 2016-02-08; baseline finish none → 2016-02-08 |
| 18 | Status Meeting 7 | 2016-02-15 A | 2016-02-15 A |  | 0% → 100% | 118.62d → none | baseline start none → 2016-02-15; baseline finish none → 2016-02-15 |
| 19 | Status Meeting 8 | 2016-02-22 A | 2016-02-22 A |  | 0% → 100% | 113.62d → none | baseline start none → 2016-02-22; baseline finish none → 2016-02-22 |
| 20 | Status Meeting 9 | 2016-02-29 A | 2016-02-29 A |  | 0% → 100% | 108.62d → none | baseline start none → 2016-02-29; baseline finish none → 2016-02-29 |
| 21 | Status Meeting 10 | 2016-03-07 A | 2016-03-07 A |  | 0% → 100% | 103.62d → none | baseline start none → 2016-03-07; baseline finish none → 2016-03-07 |
| 22 | Status Meeting 11 | 2016-03-14 A | 2016-03-14 A |  | 0% → 100% | 98.62d → none | baseline start none → 2016-03-14; baseline finish none → 2016-03-14 |
| 23 | Status Meeting 12 | 2016-03-21 A | 2016-03-21 A |  | 0% → 100% | 93.62d → none | baseline start none → 2016-03-21; baseline finish none → 2016-03-21 |
| 24 | Status Meeting 13 | 2016-03-28 A | 2016-03-28 A |  | 0% → 100% | 88.62d → none | baseline start none → 2016-03-28; baseline finish none → 2016-03-28 |
| 25 | Status Meeting 14 | 2016-04-04 A | 2016-04-04 A |  | 0% → 100% | 83.62d → none | baseline start none → 2016-04-04; baseline finish none → 2016-04-04 |
| 26 | Status Meeting 15 | 2016-04-11 A | 2016-04-11 A |  | 0% → 100% | 78.62d → none | baseline start none → 2016-04-11; baseline finish none → 2016-04-11 |
| 27 | Pre-Production complete | 2016-05-11 → 2016-05-09 A (-2d) | 2016-05-11 → 2016-05-09 A (-2d) |  | 0% → 100% | 0.25d → none | baseline start none → 2016-05-11; baseline finish none → 2016-05-11 |
| 28 | **Production** | 2016-05-11 → 2016-05-09 A (-2d) | 2016-06-23 → 2016-06-28 (+5d) | 30d → 35.5d | 0% → 78% | 0d → 0.25d | baseline start none → 2016-05-11; baseline finish none → 2016-06-23 |
| 29 | Production begins | 2016-05-11 → 2016-05-09 A (-2d) | 2016-05-11 → 2016-05-09 A (-2d) |  | 0% → 100% | 3d → none | baseline start none → 2016-05-11; baseline finish none → 2016-05-11 |
| 30 | **Scene 1** | 2016-05-11 → 2016-05-09 A (-2d) | 2016-05-20 A | 6.75d → 9.25d | 0% → 100% | 3d → none | baseline start none → 2016-05-11; baseline finish none → 2016-05-20 |
| 31 | Scene 1 begin | 2016-05-11 → 2016-05-09 A (-2d) | 2016-05-11 → 2016-05-09 A (-2d) |  | 0% → 100% | 3d → none | baseline start none → 2016-05-11; baseline finish none → 2016-05-11 |
| 32 | Scene 1 setup | 2016-05-11 A | 2016-05-13 A |  | 0% → 100% | 3d → none | baseline start none → 2016-05-11; baseline finish none → 2016-05-13 |
| 33 | Scene 1 rehearsal | 2016-05-13 A | 2016-05-16 A |  | 0% → 100% | 3d → none | baseline start none → 2016-05-13; baseline finish none → 2016-05-16 |
| 34 | Scene 1 vocal recording | 2016-05-16 A | 2016-05-17 A | 1d → 1.13d | 0% → 100% | 3d → none | baseline start none → 2016-05-16; baseline finish none → 2016-05-17 |
| 35 | Scene 1 video shoot | 2016-05-17 A | 2016-05-19 → 2016-05-20 A (+1d) | 2d → 3d | 0% → 100% | 3d → none | baseline start none → 2016-05-17; baseline finish none → 2016-05-19 |
| 36 | Scene 1 teardown | 2016-05-19 A | 2016-05-20 A |  | 0% → 100% | 3d → none | baseline start none → 2016-05-19; baseline finish none → 2016-05-20 |
| 37 | Scene 1 complete | 2016-05-20 A | 2016-05-20 A |  | 0% → 100% | 3d → none | baseline start none → 2016-05-20; baseline finish none → 2016-05-20 |
| 38 | **Scene 2** | 2016-05-25 A | 2016-06-03 A |  | 0% → 100% | 0.5d → none | baseline start none → 2016-05-25; baseline finish none → 2016-06-03 |
| 39 | Scene 2 begin | 2016-05-25 A | 2016-05-25 A |  | 0% → 100% | 0.5d → none | baseline start none → 2016-05-25; baseline finish none → 2016-05-25 |
| 40 | Scene 2 setup | 2016-05-25 A | 2016-05-26 A |  | 0% → 100% | 0.5d → none | baseline start none → 2016-05-25; baseline finish none → 2016-05-26 |
| 41 | Scene 2 rehearsal | 2016-05-27 A | 2016-05-27 → 2016-05-31 A (+4d) | 6h → 14h | 0% → 100% | 0.5d → none | baseline start none → 2016-05-27; baseline finish none → 2016-05-27 |
| 42 | Scene 2 vocal recording | 2016-05-27 A | 2016-05-31 → 2016-06-02 A (+2d) | 1d → 3d | 0% → 100% | 0.5d → none | baseline start none → 2016-05-27; baseline finish none → 2016-05-31 |
| 43 | Scene 2 video shoot | 2016-05-31 A | 2016-06-02 A |  | 0% → 100% | 0.5d → none | baseline start none → 2016-05-31; baseline finish none → 2016-06-02 |
| 44 | Scene 2 teardown | 2016-06-02 A | 2016-06-03 A |  | 0% → 100% | 0.5d → none | baseline start none → 2016-06-02; baseline finish none → 2016-06-03 |
| 45 | Scene 2 complete | 2016-06-03 A | 2016-06-03 A |  | 0% → 100% | 0.5d → none | baseline start none → 2016-06-03; baseline finish none → 2016-06-03 |
| 46 | **Scene 3** | 2016-06-03 A | 2016-06-14 → 2016-06-17 A (+3d) | 7.25d → 10.25d | 0% → 100% | 0d → none | baseline start none → 2016-06-03; baseline finish none → 2016-06-14 |
| 47 | Scene 3 begin | 2016-06-03 A | 2016-06-03 A |  | 0% → 100% | 0.5d → none | baseline start none → 2016-06-03; baseline finish none → 2016-06-03 |
| 48 | Scene 3 setup | 2016-06-03 A | 2016-06-07 → 2016-06-10 A (+3d) |  | 0% → 100% | 0.5d → none | baseline start none → 2016-06-03; baseline finish none → 2016-06-07 |
| 49 | Scene 3 rehearsal | 2016-06-07 → 2016-06-13 A (+6d) | 2016-06-08 → 2016-06-13 A (+5d) |  | 0% → 100% | 0.5d → none | constraint none → start no earlier than 2016-06-09; baseline start none → 2016-06-07; baseline finish none → 2016-06-08 |
| 50 | Scene 3 vocal recording | 2016-06-08 → 2016-06-13 A (+5d) | 2016-06-09 → 2016-06-14 A (+5d) |  | 0% → 100% | 0.5d → none | constraint none → start no earlier than 2016-06-09; baseline start none → 2016-06-08; baseline finish none → 2016-06-09 |
| 51 | Scene 3 video shoot | 2016-06-09 → 2016-06-14 A (+5d) | 2016-06-14 → 2016-06-17 A (+3d) |  | 0% → 100% | 0.25d → none | baseline start none → 2016-06-09; baseline finish none → 2016-06-14 |
| 52 | Scene 3 teardown | 2016-06-14 → 2016-06-17 A (+3d) | 2016-06-14 → 2016-06-17 A (+3d) |  | 0% → 100% | 0d → none | baseline start none → 2016-06-14; baseline finish none → 2016-06-14 |
| 53 | Scene 3 complete | 2016-06-14 → 2016-06-17 A (+3d) | 2016-06-14 → 2016-06-17 A (+3d) |  | 0% → 100% | 0d → none | baseline start none → 2016-06-14; baseline finish none → 2016-06-14 |
| 54 | **Scene 4** | 2016-06-14 → 2016-06-17 (+3d) | 2016-06-23 → 2016-06-28 (+5d) |  |  | 0d → 0.25d | baseline start none → 2016-06-14; baseline finish none → 2016-06-23 |
| 55 | Scene 4 begin | 2016-06-14 → 2016-06-17 (+3d) | 2016-06-14 → 2016-06-17 (+3d) |  |  | 0d → 0.25d | baseline start none → 2016-06-14; baseline finish none → 2016-06-14 |
| 56 | Scene 4 setup | 2016-06-15 → 2016-06-20 (+5d) | 2016-06-16 → 2016-06-21 (+5d) |  |  | 0d → 0.25d | baseline start none → 2016-06-15; baseline finish none → 2016-06-16 |
| 57 | Scene 4 rehearsal | 2016-06-17 → 2016-06-22 (+5d) | 2016-06-17 → 2016-06-22 (+5d) |  |  | 0d → 0.25d | baseline start none → 2016-06-17; baseline finish none → 2016-06-17 |
| 58 | Scene 4 vocal recording | 2016-06-17 → 2016-06-22 (+5d) | 2016-06-20 → 2016-06-23 (+3d) |  |  | 0d → 0.25d | baseline start none → 2016-06-17; baseline finish none → 2016-06-20 |
| 59 | Scene 4 video shoot | 2016-06-20 → 2016-06-23 (+3d) | 2016-06-22 → 2016-06-27 (+5d) |  |  | 0d → 0.25d | baseline start none → 2016-06-20; baseline finish none → 2016-06-22 |
| 60 | Scene 4 teardown | 2016-06-22 → 2016-06-27 (+5d) | 2016-06-23 → 2016-06-28 (+5d) |  |  | 0d → 0.25d | baseline start none → 2016-06-22; baseline finish none → 2016-06-23 |
| 61 | Scene 4 complete | 2016-06-23 → 2016-06-28 (+5d) | 2016-06-23 → 2016-06-28 (+5d) |  |  | 0d → 0.25d | resources none → Ido Ben-Sachar; Patricia Doyle; baseline start none → 2016-06-23; baseline finish none → 2016-06-23 |
| 62 | Production complete | 2016-06-23 → 2016-06-28 (+5d) | 2016-06-23 → 2016-06-28 (+5d) |  |  | 0d → 0.25d | baseline start none → 2016-06-23; baseline finish none → 2016-06-23 |
| 63 | **Post-Production** | 2016-06-23 → 2016-06-28 (+5d) | 2016-07-29 → 2016-08-04 (+6d) | 26d → 26.88d |  |  | baseline start none → 2016-06-23; baseline finish none → 2016-07-29 |
| 64 | Post-Production Begins | 2016-06-23 → 2016-06-28 (+5d) | 2016-06-23 → 2016-06-28 (+5d) |  |  | 0d → 0.25d | baseline start none → 2016-06-23; baseline finish none → 2016-06-23 |
| 65 | Log video footage | 2016-06-23 → 2016-06-28 (+5d) | 2016-06-28 → 2016-07-01 (+3d) |  |  | 0d → 0.25d | baseline start none → 2016-06-23; baseline finish none → 2016-06-28 |
| 66 | Log audio tracks by scene | 2016-06-23 → 2016-06-28 (+5d) | 2016-06-28 → 2016-07-01 (+3d) |  |  | 0d → 0.25d | baseline start none → 2016-06-23; baseline finish none → 2016-06-28 |
| 67 | Rough edit video - paper | 2016-06-28 → 2016-07-01 (+3d) | 2016-07-05 → 2016-07-08 (+3d) |  |  | 0d → 0.25d | baseline start none → 2016-06-28; baseline finish none → 2016-07-05 |
| 68 | Rough audio edit | 2016-07-05 → 2016-07-08 (+3d) | 2016-07-12 → 2016-07-15 (+3d) |  |  | 0d → 0.25d | baseline start none → 2016-07-05; baseline finish none → 2016-07-12 |
| 69 | Fine audio edit | 2016-07-12 → 2016-07-15 (+3d) | 2016-07-15 → 2016-07-20 (+5d) |  |  | 10d → 10.88d | baseline start none → 2016-07-12; baseline finish none → 2016-07-15 |
| 70 | Fine video edit | 2016-07-12 → 2016-07-15 (+3d) | 2016-07-15 → 2016-07-20 (+5d) |  |  | 0d → 0.25d | baseline start none → 2016-07-12; baseline finish none → 2016-07-15 |

| ID | Task | Start | Finish | Duration | Total float | Other |
| --- | --- | --- | --- | --- | --- | --- |
| 71 | Dub audio to video | 2016-07-15 → 2016-07-20 (+5d) | 2016-07-19 → 2016-07-22 (+3d) |  | 0d → 0.25d | baseline start none → 2016-07-15; baseline finish none → 2016-07-19 |
| 72 | Internal review viewing | 2016-07-19 → 2016-07-22 (+3d) | 2016-07-20 → 2016-07-25 (+5d) | 1d → 1.25d |  | baseline start none → 2016-07-19; baseline finish none → 2016-07-20 |
| 73 | Final edits | 2016-07-20 → 2016-07-25 (+5d) | 2016-07-25 → 2016-07-28 (+3d) | 4d → 3.75d |  | baseline start none → 2016-07-20; baseline finish none → 2016-07-25 |
| 74 | Formal approval viewing | 2016-07-25 → 2016-07-28 (+3d) | 2016-07-26 → 2016-08-01 (+6d) | 1d → 1.62d |  | baseline start none → 2016-07-25; baseline finish none → 2016-07-26 |
| 75 | Duplicate audio and video masters | 2016-07-26 → 2016-08-01 (+6d) | 2016-07-27 → 2016-08-02 (+6d) |  |  | baseline start none → 2016-07-26; baseline finish none → 2016-07-27 |
| 76 | Archive Copy 1 AV masters | 2016-07-27 → 2016-08-02 (+6d) | 2016-07-28 → 2016-08-03 (+6d) |  |  | baseline start none → 2016-07-27; baseline finish none → 2016-07-28 |
| 77 | Send Copy 2 AV master and dubbed master to | 2016-07-28 → 2016-08-03 (+6d) | 2016-07-29 → 2016-08-04 (+6d) |  |  | baseline start none → 2016-07-28; baseline finish none → 2016-07-29 |
| 78 | Post-Production complete | 2016-07-29 → 2016-08-04 (+6d) | 2016-07-29 → 2016-08-04 (+6d) |  |  | baseline start none → 2016-07-29; baseline finish none → 2016-07-29 |

## Version 8 (data date 2016-06-10, saved 2013-06-29, file donfunkmusicvideo10-1-mpp)

Last finish stays 2016-08-04. Complete tasks 47 → 41.

Changed:

| ID | Task | Start | Finish | Complete | Total float |
| --- | --- | --- | --- | --- | --- |
| 28 | **Production** |  |  | 78% → 60% |  |
| 46 | **Scene 3** |  | 2016-06-17 A → 2016-06-17 | 100% → 15% | none → 0d |
| 48 | Scene 3 setup |  | 2016-06-10 A → 2016-06-10 | 100% → 50% | none → 0.25d |
| 49 | Scene 3 rehearsal | 2016-06-13 A → 2016-06-13 | 2016-06-13 A → 2016-06-13 | 100% → 0% | none → 0.25d |
| 50 | Scene 3 vocal recording | 2016-06-13 A → 2016-06-13 | 2016-06-14 A → 2016-06-14 | 100% → 0% | none → 0.25d |
| 51 | Scene 3 video shoot | 2016-06-14 A → 2016-06-14 | 2016-06-17 A → 2016-06-17 | 100% → 0% | none → 0.25d |
| 52 | Scene 3 teardown | 2016-06-17 A → 2016-06-17 | 2016-06-17 A → 2016-06-17 | 100% → 0% | none → 0d |
| 53 | Scene 3 complete | 2016-06-17 A → 2016-06-17 | 2016-06-17 A → 2016-06-17 | 100% → 0% | none → 0d |

## Version 9 (data date 2016-06-10, saved 2013-07-01, file donfunkmusicvideo11-6-mpp)

Last finish 2016-08-04 → 2016-08-08 (+4d). Complete tasks 41 → 23.

Changed:

| ID | Task | Start | Finish | Duration | Complete | Total float | Other |
| --- | --- | --- | --- | --- | --- | --- | --- |
| 1 | **Pre-Production** |  | 2016-05-09 A → 2016-05-11 (+2d) | 89.25d → 92d | 100% → 98% | none → 61.75d |  |
| 2 | Pre-Production complete |  |  |  |  |  | was named Pre-Production begins |
| 7 | Book musicians | 2016-03-28 A → 2016-03-25 A (-3d) | 2016-04-11 A → 2016-04-07 A (-4d) |  |  |  |  |
| 8 | Book dancers | 2016-04-11 A → 2016-04-08 A (-3d) | 2016-04-25 A → 2016-04-26 A (+1d) | 2w → 13d |  |  |  |
| 9 | Reserve audio recording equipment | 2016-04-25 A → 2016-04-27 A (+2d) | 2016-05-02 A → 2016-05-03 A (+1d) |  |  |  |  |
| 10 | Reserve video recording equipment | 2016-05-02 A → 2016-05-04 A (+2d) | 2016-05-09 A → 2016-05-11 A (+2d) | 5d → 6d |  |  |  |
| 11 | **Status Meeting** | 2016-01-04 A → 2016-01-04 | 2016-04-11 A → 2016-04-11 |  | 100% → 0% | none → 84.62d |  |
| 12 | Status Meeting 1 | 2016-01-04 A → 2016-01-04 | 2016-01-04 A → 2016-01-04 |  | 100% → 0% | none → 153.62d |  |
| 13 | Status Meeting 2 | 2016-01-11 A → 2016-01-11 | 2016-01-11 A → 2016-01-11 |  | 100% → 0% | none → 148.62d |  |
| 14 | Status Meeting 3 | 2016-01-19 A → 2016-01-19 | 2016-01-19 A → 2016-01-19 |  | 100% → 0% | none → 143.62d |  |
| 15 | Status Meeting 4 | 2016-01-25 A → 2016-01-25 | 2016-01-25 A → 2016-01-25 |  | 100% → 0% | none → 139.62d |  |
| 16 | Status Meeting 5 | 2016-02-01 A → 2016-02-01 | 2016-02-01 A → 2016-02-01 |  | 100% → 0% | none → 134.62d |  |
| 17 | Status Meeting 6 | 2016-02-08 A → 2016-02-08 | 2016-02-08 A → 2016-02-08 |  | 100% → 0% | none → 129.62d |  |
| 18 | Status Meeting 7 | 2016-02-15 A → 2016-02-15 | 2016-02-15 A → 2016-02-15 |  | 100% → 0% | none → 124.62d |  |
| 19 | Status Meeting 8 | 2016-02-22 A → 2016-02-22 | 2016-02-22 A → 2016-02-22 |  | 100% → 0% | none → 119.62d |  |
| 20 | Status Meeting 9 | 2016-02-29 A → 2016-02-29 | 2016-02-29 A → 2016-02-29 |  | 100% → 0% | none → 114.62d |  |
| 21 | Status Meeting 10 | 2016-03-07 A → 2016-03-07 | 2016-03-07 A → 2016-03-07 |  | 100% → 0% | none → 109.62d |  |
| 22 | Status Meeting 11 | 2016-03-14 A → 2016-03-14 | 2016-03-14 A → 2016-03-14 |  | 100% → 0% | none → 104.62d |  |
| 23 | Status Meeting 12 | 2016-03-21 A → 2016-03-21 | 2016-03-21 A → 2016-03-21 |  | 100% → 0% | none → 99.62d |  |
| 24 | Status Meeting 13 | 2016-03-28 A → 2016-03-28 | 2016-03-28 A → 2016-03-28 |  | 100% → 0% | none → 94.62d |  |
| 25 | Status Meeting 14 | 2016-04-04 A → 2016-04-04 | 2016-04-04 A → 2016-04-04 |  | 100% → 0% | none → 89.62d |  |
| 26 | Status Meeting 15 | 2016-04-11 A → 2016-04-11 | 2016-04-11 A → 2016-04-11 |  | 100% → 0% | none → 84.62d |  |
| 27 | Pre-Production complete | 2016-05-09 A → 2016-05-11 (+2d) | 2016-05-09 A → 2016-05-11 (+2d) |  | 100% → 0% | none → 0d |  |
| 28 | **Production** | 2016-05-09 A → 2016-05-11 A (+2d) | 2016-06-28 → 2016-07-01 (+3d) | 35.5d → 35.75d | 60% → 57% |  |  |
| 29 | Production begins | 2016-05-09 A → 2016-05-11 (+2d) | 2016-05-09 A → 2016-05-11 (+2d) |  | 100% → 0% | none → 36d |  |
| 30 | **Scene 1** | 2016-05-09 A → 2016-05-11 A (+2d) | 2016-05-20 A → 2016-05-23 A (+3d) | 9.25d → 7.88d |  |  |  |
| 31 | Scene 1 begin | 2016-05-09 A → 2016-05-11 A (+2d) | 2016-05-09 A → 2016-05-11 A (+2d) |  |  |  |  |
| 32 | Scene 1 setup | 2016-05-11 A → 2016-05-12 A (+1d) |  |  |  |  |  |
| 33 | Scene 1 rehearsal | 2016-05-13 A → 2016-05-16 A (+3d) |  |  |  |  |  |
| 36 | Scene 1 teardown | 2016-05-19 A → 2016-05-20 A (+1d) | 2016-05-20 A → 2016-05-23 A (+3d) |  |  |  |  |
| 37 | Scene 1 complete | 2016-05-20 A → 2016-05-23 A (+3d) | 2016-05-20 A → 2016-05-23 A (+3d) |  |  |  |  |
| 38 | **Scene 2** |  | 2016-06-03 A → 2016-06-08 A (+5d) | 6.75d → 9.75d |  |  |  |
| 42 | Scene 2 vocal recording | 2016-05-27 A → 2016-05-31 A (+4d) | 2016-06-02 A → 2016-06-03 A (+1d) |  |  |  |  |
| 43 | Scene 2 video shoot | 2016-05-31 A → 2016-06-03 A (+3d) | 2016-06-02 A → 2016-06-07 A (+5d) |  |  |  |  |
| 44 | Scene 2 teardown | 2016-06-02 A → 2016-06-07 A (+5d) | 2016-06-03 A → 2016-06-08 A (+5d) |  |  |  |  |
| 45 | Scene 2 complete | 2016-06-03 A → 2016-06-08 A (+5d) | 2016-06-03 A → 2016-06-08 A (+5d) |  |  |  |  |
| 46 | **Scene 3** | 2016-06-03 A → 2016-06-08 (+5d) | 2016-06-17 → 2016-06-22 (+5d) |  | 15% → 0% |  |  |
| 47 | Scene 3 begin | 2016-06-03 A → 2016-06-08 (+5d) | 2016-06-03 A → 2016-06-08 (+5d) |  | 100% → 0% | none → 0.25d |  |
| 48 | Scene 3 setup | 2016-06-03 A → 2016-06-08 (+5d) | 2016-06-10 → 2016-06-15 (+5d) |  | 50% → 0% |  |  |
| 49 | Scene 3 rehearsal | 2016-06-13 → 2016-06-16 (+3d) | 2016-06-13 → 2016-06-16 (+3d) |  |  |  |  |
| 50 | Scene 3 vocal recording | 2016-06-13 → 2016-06-16 (+3d) | 2016-06-14 → 2016-06-17 (+3d) |  |  |  |  |
| 51 | Scene 3 video shoot | 2016-06-14 → 2016-06-17 (+3d) | 2016-06-17 → 2016-06-22 (+5d) |  |  |  |  |
| 52 | Scene 3 teardown | 2016-06-17 → 2016-06-22 (+5d) | 2016-06-17 → 2016-06-22 (+5d) |  |  |  |  |
| 53 | Scene 3 complete | 2016-06-17 → 2016-06-22 (+5d) | 2016-06-17 → 2016-06-22 (+5d) |  |  |  |  |
| 54 | **Scene 4** | 2016-06-17 → 2016-06-22 (+5d) | 2016-06-28 → 2016-07-01 (+3d) |  |  | 0.25d → 0d |  |
| 55 | Scene 4 begin | 2016-06-17 → 2016-06-22 (+5d) | 2016-06-17 → 2016-06-22 (+5d) |  |  | 0.25d → 0d |  |
| 56 | Scene 4 setup | 2016-06-20 → 2016-06-23 (+3d) | 2016-06-21 → 2016-06-24 (+3d) |  |  | 0.25d → 0d |  |
| 57 | Scene 4 rehearsal | 2016-06-22 → 2016-06-27 (+5d) | 2016-06-22 → 2016-06-27 (+5d) |  |  | 0.25d → 0d |  |
| 58 | Scene 4 vocal recording | 2016-06-22 → 2016-06-27 (+5d) | 2016-06-23 → 2016-06-28 (+5d) |  |  | 0.25d → 0d |  |
| 59 | Scene 4 video shoot | 2016-06-23 → 2016-06-28 (+5d) | 2016-06-27 → 2016-06-30 (+3d) |  |  | 0.25d → 0d |  |
| 60 | Scene 4 teardown | 2016-06-27 → 2016-06-30 (+3d) | 2016-06-28 → 2016-07-01 (+3d) |  |  | 0.25d → 0d |  |
| 61 | Scene 4 complete | 2016-06-28 → 2016-07-01 (+3d) | 2016-06-28 → 2016-07-01 (+3d) |  |  | 0.25d → 0d |  |
| 62 | Production complete | 2016-06-28 → 2016-07-01 (+3d) | 2016-06-28 → 2016-07-01 (+3d) |  |  | 0.25d → 0d |  |
| 63 | **Post-Production** | 2016-06-28 → 2016-07-01 (+3d) | 2016-08-04 → 2016-08-08 (+4d) | 26.88d → 26d |  |  |  |
| 64 | Post-Production Begins | 2016-06-28 → 2016-07-01 (+3d) | 2016-06-28 → 2016-07-01 (+3d) |  |  | 0.25d → 0d |  |
| 65 | Log video footage | 2016-06-28 → 2016-07-01 (+3d) | 2016-07-01 → 2016-07-06 (+5d) |  |  | 0.25d → 0d |  |
| 66 | Log audio tracks by scene | 2016-06-28 → 2016-07-01 (+3d) | 2016-07-01 → 2016-07-06 (+5d) |  |  | 0.25d → 0d |  |
| 67 | Rough edit video - paper | 2016-07-01 → 2016-07-06 (+5d) | 2016-07-08 → 2016-07-13 (+5d) |  |  | 0.25d → 0d |  |
| 68 | Rough audio edit | 2016-07-08 → 2016-07-13 (+5d) | 2016-07-15 → 2016-07-20 (+5d) |  |  | 0.25d → 0d |  |
| 69 | Fine audio edit | 2016-07-15 → 2016-07-20 (+5d) | 2016-07-20 → 2016-07-25 (+5d) |  |  | 10.88d → 10d |  |
| 70 | Fine video edit | 2016-07-15 → 2016-07-20 (+5d) | 2016-07-20 → 2016-07-25 (+5d) |  |  | 0.25d → 0d |  |
| 71 | Dub audio to video | 2016-07-20 → 2016-07-25 (+5d) | 2016-07-22 → 2016-07-27 (+5d) |  |  | 0.25d → 0d |  |
| 72 | Internal review viewing | 2016-07-22 → 2016-07-27 (+5d) | 2016-07-25 → 2016-07-28 (+3d) | 1.25d → 1d |  |  |  |
| 73 | Final edits | 2016-07-25 → 2016-07-28 (+3d) | 2016-07-28 → 2016-08-02 (+5d) | 3.75d → 4d |  |  |  |
| 74 | Formal approval viewing | 2016-07-28 → 2016-08-02 (+5d) | 2016-08-01 → 2016-08-03 (+2d) | 1.62d → 1d |  |  |  |
| 75 | Duplicate audio and video masters | 2016-08-01 → 2016-08-03 (+2d) | 2016-08-02 → 2016-08-04 (+2d) |  |  |  |  |
| 76 | Archive Copy 1 AV masters | 2016-08-02 → 2016-08-04 (+2d) | 2016-08-03 → 2016-08-05 (+2d) |  |  |  |  |
| 77 | Send Copy 2 AV master and dubbed master to | 2016-08-03 → 2016-08-05 (+2d) | 2016-08-04 → 2016-08-08 (+4d) |  |  |  |  |
| 78 | Post-Production complete | 2016-08-04 → 2016-08-08 (+4d) | 2016-08-04 → 2016-08-08 (+4d) |  |  |  |  |

## Version 10 (data date 2016-06-10, saved 2013-07-01, file donfunkmusicvideo12-1-mpp)

Last finish 2016-08-08 → 2016-08-11 (+3d). Complete tasks 23 → 25.

Changed:

| ID | Task | Start | Finish | Duration | Complete | Total float |
| --- | --- | --- | --- | --- | --- | --- |
| 28 | **Production** |  | 2016-07-01 → 2016-07-05 (+4d) | 35.75d → 37.75d | 57% → 67% | 0.25d → -1.75d |
| 46 | **Scene 3** | 2016-06-08 A | 2016-06-22 → 2016-06-24 (+2d) | 10.25d → 12.25d | 0% → 51% |  |
| 47 | Scene 3 begin | 2016-06-08 A | 2016-06-08 A |  | 0% → 100% | 0.25d → none |
| 48 | Scene 3 setup | 2016-06-08 A | 2016-06-15 → 2016-06-17 A (+2d) | 2d → 4d | 0% → 100% | 0.25d → none |
| 49 | Scene 3 rehearsal | 2016-06-16 → 2016-06-20 A (+4d) | 2016-06-16 → 2016-06-20 (+4d) | 6h → 6.67h | 0% → 60% | 0.25d → -1.83d |
| 50 | Scene 3 vocal recording | 2016-06-16 → 2016-06-20 (+4d) | 2016-06-17 → 2016-06-21 (+4d) |  |  | 0.25d → -1.83d |
| 51 | Scene 3 video shoot | 2016-06-17 → 2016-06-21 (+4d) | 2016-06-22 → 2016-06-24 (+2d) |  |  | 0.25d → -1.25d |
| 52 | Scene 3 teardown | 2016-06-22 → 2016-06-24 (+2d) | 2016-06-22 → 2016-06-24 (+2d) |  |  | 0d → -1.75d |
| 53 | Scene 3 complete | 2016-06-22 → 2016-06-24 (+2d) | 2016-06-22 → 2016-06-24 (+2d) |  |  | 0d → -1.75d |
| 54 | **Scene 4** | 2016-06-22 → 2016-06-24 (+2d) | 2016-07-01 → 2016-07-05 (+4d) |  |  | 0d → -1.75d |
| 55 | Scene 4 begin | 2016-06-22 → 2016-06-24 (+2d) | 2016-06-22 → 2016-06-24 (+2d) |  |  | 0d → -1.75d |
| 56 | Scene 4 setup | 2016-06-23 → 2016-06-27 (+4d) | 2016-06-24 → 2016-06-28 (+4d) |  |  | 0d → -1.75d |
| 57 | Scene 4 rehearsal | 2016-06-27 → 2016-06-29 (+2d) | 2016-06-27 → 2016-06-29 (+2d) |  |  | 0d → -1.75d |
| 58 | Scene 4 vocal recording | 2016-06-27 → 2016-06-29 (+2d) | 2016-06-28 → 2016-06-30 (+2d) |  |  | 0d → -1.75d |
| 59 | Scene 4 video shoot | 2016-06-28 → 2016-06-30 (+2d) | 2016-06-30 → 2016-07-04 (+4d) |  |  | 0d → -1.75d |
| 60 | Scene 4 teardown | 2016-06-30 → 2016-07-04 (+4d) | 2016-07-01 → 2016-07-05 (+4d) |  |  | 0d → -1.75d |
| 61 | Scene 4 complete | 2016-07-01 → 2016-07-05 (+4d) | 2016-07-01 → 2016-07-05 (+4d) |  |  | 0d → -1.75d |
| 62 | Production complete | 2016-07-01 → 2016-07-05 (+4d) | 2016-07-01 → 2016-07-05 (+4d) |  |  | 0d → -1.75d |
| 63 | **Post-Production** | 2016-07-01 → 2016-07-05 (+4d) | 2016-08-08 → 2016-08-11 (+3d) | 26d → 26.88d |  |  |
| 64 | Post-Production Begins | 2016-07-01 → 2016-07-05 (+4d) | 2016-07-01 → 2016-07-05 (+4d) |  |  | 0d → 0.25d |
| 65 | Log video footage | 2016-07-01 → 2016-07-05 (+4d) | 2016-07-06 → 2016-07-08 (+2d) |  |  | 0d → 0.25d |
| 66 | Log audio tracks by scene | 2016-07-01 → 2016-07-05 (+4d) | 2016-07-06 → 2016-07-08 (+2d) |  |  | 0d → 0.25d |
| 67 | Rough edit video - paper | 2016-07-06 → 2016-07-08 (+2d) | 2016-07-13 → 2016-07-15 (+2d) |  |  | 0d → 0.25d |
| 68 | Rough audio edit | 2016-07-13 → 2016-07-15 (+2d) | 2016-07-20 → 2016-07-22 (+2d) |  |  | 0d → 0.25d |
| 69 | Fine audio edit | 2016-07-20 → 2016-07-22 (+2d) | 2016-07-25 → 2016-07-27 (+2d) |  |  | 10d → 10.88d |
| 70 | Fine video edit | 2016-07-20 → 2016-07-22 (+2d) | 2016-07-25 → 2016-07-27 (+2d) |  |  | 0d → 0.25d |
| 71 | Dub audio to video | 2016-07-25 → 2016-07-27 (+2d) | 2016-07-27 → 2016-07-29 (+2d) |  |  | 0d → 0.25d |
| 72 | Internal review viewing | 2016-07-27 → 2016-07-29 (+2d) | 2016-07-28 → 2016-08-01 (+4d) | 1d → 1.25d |  |  |
| 73 | Final edits | 2016-07-28 → 2016-08-01 (+4d) | 2016-08-02 → 2016-08-04 (+2d) | 4d → 3.75d |  |  |
| 74 | Formal approval viewing | 2016-08-02 → 2016-08-04 (+2d) | 2016-08-03 → 2016-08-08 (+5d) | 1d → 1.62d |  |  |
| 75 | Duplicate audio and video masters | 2016-08-03 → 2016-08-08 (+5d) | 2016-08-04 → 2016-08-09 (+5d) |  |  |  |
| 76 | Archive Copy 1 AV masters | 2016-08-04 → 2016-08-09 (+5d) | 2016-08-05 → 2016-08-10 (+5d) |  |  |  |
| 77 | Send Copy 2 AV master and dubbed master to | 2016-08-05 → 2016-08-10 (+5d) | 2016-08-08 → 2016-08-11 (+3d) |  |  |  |
| 78 | Post-Production complete | 2016-08-08 → 2016-08-11 (+3d) | 2016-08-08 → 2016-08-11 (+3d) |  |  |  |

## Version 11 (data date 2016-06-10, saved 2013-07-04, file donfunkmusicvideo13-4-mpp)

Last finish stays 2016-08-11. Complete tasks 25 → 0.

Changed:

| ID | Task | Start | Finish | Duration | Complete | Total float |
| --- | --- | --- | --- | --- | --- | --- |
| 1 | **Pre-Production** | 2016-01-04 A → 2016-01-04 | 2016-05-11 → 2016-05-12 (+1d) | 92d → 92.88d | 98% → 0% | 64.62d → -2.46d |
| 2 | Pre-Production complete | 2016-01-04 A → 2016-01-04 | 2016-01-04 A → 2016-01-04 |  | 100% → 0% | none → -2.46d |
| 3 | Review screenplay | 2016-01-04 A → 2016-01-04 | 2016-01-26 A → 2016-01-26 |  | 100% → 0% | none → -2.46d |
| 4 | Develop scene blocking and schedule | 2016-01-26 A → 2016-01-26 | 2016-02-04 A → 2016-02-04 |  | 100% → 0% | none → -2.46d |
| 5 | Develop production layouts | 2016-02-05 A → 2016-02-05 | 2016-02-24 A → 2016-02-24 |  | 100% → 0% | none → -1.59d |
| 6 | Identify and reserve locations | 2016-02-24 A → 2016-02-24 | 2016-03-28 A → 2016-03-25 (-3d) |  | 100% → 0% | none → -1.59d |
| 7 | Book musicians | 2016-03-25 A → 2016-03-25 | 2016-04-07 A → 2016-04-08 (+1d) |  | 100% → 0% | none → -1.59d |
| 8 | Book dancers | 2016-04-08 A → 2016-04-08 | 2016-04-26 A → 2016-04-27 (+1d) |  | 100% → 0% | none → -1.59d |
| 9 | Reserve audio recording equipment | 2016-04-27 A → 2016-04-27 | 2016-05-03 A → 2016-05-04 (+1d) |  | 100% → 0% | none → -1.59d |
| 10 | Reserve video recording equipment | 2016-05-04 A → 2016-05-04 | 2016-05-11 A → 2016-05-12 (+1d) |  | 100% → 0% | none → -1.59d |
| 27 | Pre-Production complete | 2016-05-11 → 2016-05-12 (+1d) | 2016-05-11 → 2016-05-12 (+1d) |  |  | 0d → -1.59d |
| 28 | **Production** | 2016-05-11 A → 2016-05-12 (+1d) |  | 37.75d → 36.88d | 67% → 0% |  |
| 29 | Production begins | 2016-05-11 → 2016-05-12 (+1d) | 2016-05-11 → 2016-05-12 (+1d) |  |  | 36d → -1.59d |
| 30 | **Scene 1** | 2016-05-11 A → 2016-05-12 (+1d) | 2016-05-23 A → 2016-05-24 (+1d) |  | 100% → 0% | none → -1.59d |
| 31 | Scene 1 begin | 2016-05-11 A → 2016-05-12 (+1d) | 2016-05-11 A → 2016-05-12 (+1d) |  | 100% → 0% | none → -1.59d |
| 32 | Scene 1 setup | 2016-05-12 A → 2016-05-12 | 2016-05-13 A → 2016-05-16 (+3d) |  | 100% → 0% | none → -1.59d |
| 33 | Scene 1 rehearsal | 2016-05-16 A → 2016-05-16 | 2016-05-16 A → 2016-05-17 (+1d) |  | 100% → 0% | none → -1.59d |
| 34 | Scene 1 vocal recording | 2016-05-16 A → 2016-05-17 (+1d) | 2016-05-17 A → 2016-05-18 (+1d) |  | 100% → 0% | none → -1.59d |
| 35 | Scene 1 video shoot | 2016-05-17 A → 2016-05-18 (+1d) | 2016-05-20 A → 2016-05-23 (+3d) |  | 100% → 0% | none → -1.59d |
| 36 | Scene 1 teardown | 2016-05-20 A → 2016-05-23 (+3d) | 2016-05-23 A → 2016-05-24 (+1d) |  | 100% → 0% | none → -1.59d |
| 37 | Scene 1 complete | 2016-05-23 A → 2016-05-24 (+1d) | 2016-05-23 A → 2016-05-24 (+1d) |  | 100% → 0% | none → -1.59d |
| 38 | **Scene 2** | 2016-05-25 A → 2016-05-25 | 2016-06-08 A → 2016-06-08 |  | 100% → 0% | none → -1.83d |
| 39 | Scene 2 begin | 2016-05-25 A → 2016-05-25 | 2016-05-25 A → 2016-05-25 |  | 100% → 0% | none → -1.83d |
| 40 | Scene 2 setup | 2016-05-25 A → 2016-05-25 | 2016-05-26 A → 2016-05-26 |  | 100% → 0% | none → -1.83d |
| 41 | Scene 2 rehearsal | 2016-05-27 A → 2016-05-27 | 2016-05-31 A → 2016-05-31 |  | 100% → 0% | none → -1.83d |
| 42 | Scene 2 vocal recording | 2016-05-31 A → 2016-05-31 | 2016-06-03 A → 2016-06-03 |  | 100% → 0% | none → -1.83d |
| 43 | Scene 2 video shoot | 2016-06-03 A → 2016-06-03 | 2016-06-07 A → 2016-06-07 |  | 100% → 0% | none → -1.83d |
| 44 | Scene 2 teardown | 2016-06-07 A → 2016-06-07 | 2016-06-08 A → 2016-06-08 |  | 100% → 0% | none → -1.83d |
| 45 | Scene 2 complete | 2016-06-08 A → 2016-06-08 | 2016-06-08 A → 2016-06-08 |  | 100% → 0% | none → -1.83d |
| 46 | **Scene 3** | 2016-06-08 A → 2016-06-08 |  |  | 51% → 0% | 0d → -1.83d |
| 47 | Scene 3 begin | 2016-06-08 A → 2016-06-08 | 2016-06-08 A → 2016-06-08 |  | 100% → 0% | none → -1.83d |
| 48 | Scene 3 setup | 2016-06-08 A → 2016-06-08 | 2016-06-17 A → 2016-06-17 |  | 100% → 0% | none → -1.83d |
| 49 | Scene 3 rehearsal | 2016-06-20 A → 2016-06-20 |  |  | 60% → 0% |  |

## Version 12 (data date 2016-06-10, saved 2013-07-04, file donfunkmusicvideo14-2-mpp)

Last finish stays 2016-08-11. Complete tasks 0 → 25.

Changed:

| ID | Task | Start | Finish | Duration | Complete | Total float |
| --- | --- | --- | --- | --- | --- | --- |
| 1 | **Pre-Production** | 2016-01-04 A | 2016-05-12 → 2016-05-11 (-1d) | 92.88d → 92d | 0% → 98% | -2.46d → 64.62d |
| 2 | Pre-Production complete | 2016-01-04 A | 2016-01-04 A |  | 0% → 100% | -2.46d → none |
| 3 | Review screenplay | 2016-01-04 A | 2016-01-26 A |  | 0% → 100% | -2.46d → none |
| 4 | Develop scene blocking and schedule | 2016-01-26 A | 2016-02-04 A |  | 0% → 100% | -2.46d → none |
| 5 | Develop production layouts | 2016-02-05 A | 2016-02-24 A |  | 0% → 100% | -1.59d → none |
| 6 | Identify and reserve locations | 2016-02-24 A | 2016-03-25 → 2016-03-28 A (+3d) |  | 0% → 100% | -1.59d → none |
| 7 | Book musicians | 2016-03-25 A | 2016-04-08 → 2016-04-07 A (-1d) |  | 0% → 100% | -1.59d → none |
| 8 | Book dancers | 2016-04-08 A | 2016-04-27 → 2016-04-26 A (-1d) |  | 0% → 100% | -1.59d → none |
| 9 | Reserve audio recording equipment | 2016-04-27 A | 2016-05-04 → 2016-05-03 A (-1d) |  | 0% → 100% | -1.59d → none |
| 10 | Reserve video recording equipment | 2016-05-04 A | 2016-05-12 → 2016-05-11 A (-1d) |  | 0% → 100% | -1.59d → none |
| 27 | Pre-Production complete | 2016-05-12 → 2016-05-11 (-1d) | 2016-05-12 → 2016-05-11 (-1d) |  |  | -1.59d → 0d |
| 28 | **Production** | 2016-05-12 → 2016-05-11 A (-1d) |  | 36.88d → 37.75d | 0% → 67% |  |
| 29 | Production begins | 2016-05-12 → 2016-05-11 (-1d) | 2016-05-12 → 2016-05-11 (-1d) |  |  | -1.59d → 36d |
| 30 | **Scene 1** | 2016-05-12 → 2016-05-11 A (-1d) | 2016-05-24 → 2016-05-23 A (-1d) |  | 0% → 100% | -1.59d → none |
| 31 | Scene 1 begin | 2016-05-12 → 2016-05-11 A (-1d) | 2016-05-12 → 2016-05-11 A (-1d) |  | 0% → 100% | -1.59d → none |
| 32 | Scene 1 setup | 2016-05-12 A | 2016-05-16 → 2016-05-13 A (-3d) |  | 0% → 100% | -1.59d → none |
| 33 | Scene 1 rehearsal | 2016-05-16 A | 2016-05-17 → 2016-05-16 A (-1d) |  | 0% → 100% | -1.59d → none |
| 34 | Scene 1 vocal recording | 2016-05-17 → 2016-05-16 A (-1d) | 2016-05-18 → 2016-05-17 A (-1d) |  | 0% → 100% | -1.59d → none |
| 35 | Scene 1 video shoot | 2016-05-18 → 2016-05-17 A (-1d) | 2016-05-23 → 2016-05-20 A (-3d) |  | 0% → 100% | -1.59d → none |
| 36 | Scene 1 teardown | 2016-05-23 → 2016-05-20 A (-3d) | 2016-05-24 → 2016-05-23 A (-1d) |  | 0% → 100% | -1.59d → none |
| 37 | Scene 1 complete | 2016-05-24 → 2016-05-23 A (-1d) | 2016-05-24 → 2016-05-23 A (-1d) |  | 0% → 100% | -1.59d → none |
| 38 | **Scene 2** | 2016-05-25 A | 2016-06-08 A |  | 0% → 100% | -1.83d → none |
| 39 | Scene 2 begin | 2016-05-25 A | 2016-05-25 A |  | 0% → 100% | -1.83d → none |
| 40 | Scene 2 setup | 2016-05-25 A | 2016-05-26 A |  | 0% → 100% | -1.83d → none |
| 41 | Scene 2 rehearsal | 2016-05-27 A | 2016-05-31 A |  | 0% → 100% | -1.83d → none |
| 42 | Scene 2 vocal recording | 2016-05-31 A | 2016-06-03 A |  | 0% → 100% | -1.83d → none |
| 43 | Scene 2 video shoot | 2016-06-03 A | 2016-06-07 A |  | 0% → 100% | -1.83d → none |
| 44 | Scene 2 teardown | 2016-06-07 A | 2016-06-08 A |  | 0% → 100% | -1.83d → none |
| 45 | Scene 2 complete | 2016-06-08 A | 2016-06-08 A |  | 0% → 100% | -1.83d → none |
| 46 | **Scene 3** | 2016-06-08 A |  |  | 0% → 51% | -1.83d → 0d |
| 47 | Scene 3 begin | 2016-06-08 A | 2016-06-08 A |  | 0% → 100% | -1.83d → none |
| 48 | Scene 3 setup | 2016-06-08 A | 2016-06-17 A |  | 0% → 100% | -1.83d → none |
| 49 | Scene 3 rehearsal | 2016-06-20 A |  |  | 0% → 60% |  |
