# Consumer Market Study

How a schedule from MS Project changed from version to version. A marks actual dates.

## Version 1 (saved 2026-05-24, file msprojecttwo-mpp)

| ID | WBS | Task | Duration | Start | Finish | Predecessors | Complete | Total float |
| --- | --- | --- | --- | --- | --- | --- | --- | --- |
| 1 | 1 | **Questionnaire** | 110d | 2018-01-12 A | 2018-06-14 |  | 22% | 0d |
| 2 | 1.1 | **Design** | 47d | 2018-01-12 A | 2018-03-19 |  | 64% | 58d |
| 3 |  | Identify Target Consumers | 2d | 2018-01-12 A | 2018-01-15 A |  | 100% |  |
| 4 |  | Develop Draft Questionnaire | 9d | 2018-01-16 A | 2018-01-26 A | 3 | 100% |  |
| 5 |  | Pilot Test Questionnaire | 19d | 2018-01-29 A | 2018-02-22 A | 4 | 100% |  |
| 6 |  | Review Comments & Finalize Questionnaire | 15d | 2018-02-23 A | 2018-03-15 | 5 | 1% | 0d |
| 7 |  | Develop Software Test Data | 2d | 2018-03-16 | 2018-03-19 | 6 |  | 58d |
| 8 | 1.2 | **Responses** | 87d | 2018-02-14 | 2018-06-14 |  |  | 0d |
| 9 |  | Order New Database for Labels | 21d | 2018-02-14 | 2018-03-14 |  |  |  |
| 10 |  | Print Questionnaire | 10d | 2018-03-16 | 2018-03-29 | 6 |  | 0d |
| 11 |  | Prepare Mailing Labels | 2d | 2018-03-16 | 2018-03-19 | 6, 9 |  | 8d |
| 12 |  | Mail Questionnaire & Get Responses | 55d | 2018-03-30 | 2018-06-14 | 10, 11 |  | 0d |
| 13 | 2 | **Report** | 90d | 2018-03-16 | 2018-07-19 |  |  | 0d |
| 14 | 2.1 | **Software** | 17d | 2018-03-16 | 2018-04-09 |  |  | 48d |
| 15 |  | Develop Data Analysis Software | 12d | 2018-03-16 | 2018-04-02 | 6 |  | 48d |
| 16 |  | Test Software | 5d | 2018-04-03 | 2018-04-09 | 7, 15 |  | 48d |
| 17 | 2.2 | **Report** | 25d | 2018-06-15 | 2018-07-19 |  |  | 0d |
| 18 |  | Input Response Data | 7d | 2018-06-15 | 2018-06-25 | 12, 16 |  | 0d |
| 19 |  | Analyze Results | 8d | 2018-06-26 | 2018-07-05 | 18 |  | 0d |
| 20 |  | Prepare Report | 10d | 2018-07-06 | 2018-07-19 | 19 |  | 0d |

## Version 2 (saved 2026-06-08, file msproject3-mpp-10566107)

Last finish 2018-07-19 → 2018-07-10 (-9d). Complete tasks 3 → 0.

Removed: 9 Order New Database for Labels

Changed:

| ID | Task | Start | Finish | Duration | Complete | Total float | Predecessors | Other |
| --- | --- | --- | --- | --- | --- | --- | --- | --- |
| 1 | **Questionnaire** | 2018-01-12 A → 2018-01-12 | 2018-06-14 → 2018-06-05 (-9d) | 110d → 103d | 22% → 0% |  |  |  |
| 2 | **Design** | 2018-01-12 A → 2018-01-12 | 2018-03-19 → 2018-03-08 (-11d) | 47d → 40d | 64% → 0% | 58d → 0d |  |  |
| 3 | Identify Target Consumers | 2018-01-12 A → 2018-01-12 | 2018-01-15 A → 2018-01-16 (+1d) | 2d → 3d | 100% → 0% | none → 0d |  |  |
| 4 | Develop Draft Questionnaire | 2018-01-16 A → 2018-01-17 (+1d) | 2018-01-26 A → 2018-01-30 (+4d) | 9d → 10d | 100% → 0% | none → 0d |  |  |
| 5 | Pilot Test Questionnaire | 2018-01-29 A → 2018-01-31 (+2d) | 2018-02-22 A → 2018-02-27 (+5d) | 19d → 20d | 100% → 0% | none → 0d |  | resources Susan → Susan; Travel Expense [0.1%] |
| 6 | Review Comments & Finalize Questionnaire | 2018-02-23 A → 2018-02-28 (+5d) | 2018-03-15 → 2018-03-06 (-9d) | 15d → 5d | 1% → 0% |  |  |  |
| 7 | Develop Software Test Data | 2018-03-16 → 2018-03-07 (-9d) | 2018-03-19 → 2018-03-08 (-11d) |  |  |  |  |  |
| 8 | **Responses** | 2018-02-14 → 2018-03-07 (+21d) | 2018-06-14 → 2018-06-05 (-9d) | 87d → 65d |  |  |  |  |
| 9 | Print Questionnaire | 2018-03-16 → 2018-03-07 (-9d) | 2018-03-29 → 2018-03-20 (-9d) |  |  |  |  | resources Steve → Steve; Questionnaire Printing |
| 10 | Prepare Mailing Labels | 2018-03-16 → 2018-03-08 (-8d) | 2018-03-19 → 2018-03-09 (-10d) |  |  | 8d → 7d | 6, Order New Database for Labels → 6 | baseline start 2018-03-07 → 2018-03-08; baseline finish 2018-03-08 → 2018-03-09 |
| 11 | Mail Questionnaire & Get Responses | 2018-03-30 → 2018-03-21 (-9d) | 2018-06-14 → 2018-06-05 (-9d) |  |  |  |  | resources Steve → Steve; Questionnaire Mailing |
| 12 | **Report** | 2018-03-16 → 2018-03-07 (-9d) | 2018-07-19 → 2018-07-10 (-9d) |  |  |  |  |  |
| 13 | **Software** | 2018-03-16 → 2018-03-07 (-9d) | 2018-04-09 → 2018-03-29 (-11d) |  |  |  |  |  |
| 14 | Develop Data Analysis Software | 2018-03-16 → 2018-03-07 (-9d) | 2018-04-02 → 2018-03-22 (-11d) |  |  |  |  |  |
| 15 | Test Software | 2018-04-03 → 2018-03-23 (-11d) | 2018-04-09 → 2018-03-29 (-11d) |  |  |  |  |  |
| 16 | **Report** | 2018-06-15 → 2018-06-06 (-9d) | 2018-07-19 → 2018-07-10 (-9d) |  |  |  |  |  |
| 17 | Input Response Data | 2018-06-15 → 2018-06-06 (-9d) | 2018-06-25 → 2018-06-14 (-11d) |  |  |  |  |  |
| 18 | Analyze Results | 2018-06-26 → 2018-06-15 (-11d) | 2018-07-05 → 2018-06-26 (-9d) |  |  |  |  |  |
| 19 | Prepare Report | 2018-07-06 → 2018-06-27 (-9d) | 2018-07-19 → 2018-07-10 (-9d) |  |  |  |  |  |
