# Online Retail Grocery Store website’s software development

How a schedule from MS Project changed from version to version. A marks actual dates.

## Version 1 (saved 2021-04-12, file pmgt699wbs-mpp-7377503)

| ID | WBS | Task | Duration | Start | Finish | Predecessors | Total float | Constraint |
| --- | --- | --- | --- | --- | --- | --- | --- | --- |
| 1 |  | Online Retail Grocery Store website’s software development | 190d | 2021-04-05 | 2021-12-31 |  | 0d | start no earlier than 2021-04-05 |
| 2 | 1 | **Project Management** | 190d? | 2021-04-05 | 2021-12-31 |  |  |  |
| 3 | 2 | **Project Initiation** | 15d? | 2021-04-05 | 2021-04-23 |  |  |  |
| 4 |  | Project Charter Review | 2d? | 2021-04-05 | 2021-04-06 |  | 174d | finish no earlier than 2021-04-06 |
| 5 |  | Project proposal Evaluation | 3d | 2021-04-07 | 2021-04-09 | 4 | 174d | start no earlier than 2021-04-07 |
| 6 |  | Project Kick off Meeting | 1d | 2021-04-12 | 2021-04-12 | 5 | 174d | start no earlier than 2021-04-12 |
| 7 |  | Project Vision and Mission Statement | 1d? | 2021-04-13 | 2021-04-13 |  | 183d | start no earlier than 2021-04-13 |
| 8 |  | Defining Problem Statement | 1d? | 2021-04-14 | 2021-04-14 |  | 182d | start no earlier than 2021-04-14 |
| 9 |  | Onboarding of project resources | 1d? | 2021-04-15 | 2021-04-15 | 6 | 172d | start no earlier than 2021-04-15 |
| 10 |  | Documentation of Project Charter | 3d | 2021-04-16 | 2021-04-20 | 9 | 172d | start no earlier than 2021-04-15 |
| 11 |  | Signatures on Project Charter Team | 1d? | 2021-04-21 | 2021-04-21 | 10 | 172d | start no earlier than 2021-04-19 |
| 12 |  | Defining Responsibilties and goals | 1d? | 2021-04-22 | 2021-04-22 | 11 | 172d | start no earlier than 2021-04-20 |
| 13 |  | Project Charter Document completion | 1d? | 2021-04-23 | 2021-04-23 | 12 | 172d | start no earlier than 2021-04-21 |
| 14 |  | Project Charter Approved | 0d | 2021-04-23 | 2021-04-23 |  | 175d | start no earlier than 2021-04-23 |
| 15 |  | Project Initiation Phase End | 0d | 2021-04-23 | 2021-04-23 |  | 174d | start no earlier than 2021-04-23 |
| 16 | 3 | **Project Planning** | 45d? | 2021-04-26 | 2021-06-28 |  |  |  |
| 17 |  | Review Project Documentation | 1d? | 2021-04-26 | 2021-04-26 |  | 172d | start no earlier than 2021-04-26 |
| 18 |  | Create a PMP Draft Template | 1d? | 2021-04-27 | 2021-04-27 | 17 | 172d | start no earlier than 2021-04-27 |
| 19 |  | Review the draft PMP with project team | 1d? | 2021-04-28 | 2021-04-28 | 17, 18 | 172d | start no earlier than 2021-04-28 |
| 20 |  | Review/Approve PMP with Project Sponsor | 1d? | 2021-04-29 | 2021-04-29 |  | 171d | start no earlier than 2021-04-29 |
| 21 |  | PMP Approval | 0d | 2021-04-29 | 2021-04-29 | 20 | 171d | start no earlier than 2021-04-29 |
| 22 | 3.6 | **Tool and Technology Selection** | 2d? | 2021-04-30 | 2021-05-03 |  |  |  |
| 23 |  | MS SQL | 1d? | 2021-04-30 | 2021-04-30 |  | 169d |  |
| 24 |  | Dot Net Technology | 1d? | 2021-05-03 | 2021-05-03 | 23 | 169d | start no earlier than 2021-05-03 |
| 25 |  | License Approval on Tool and Technology | 0d | 2021-05-03 | 2021-05-03 |  | 170d | start no earlier than 2021-05-03 |
| 26 |  | Development of Organizational Chart which includes who reports to whom | 2d? | 2021-05-04 | 2021-05-05 |  | 167d | start no earlier than 2021-05-04 |
| 27 | 3.8 | **Template selection of Website** | 2d? | 2021-05-06 | 2021-05-07 |  |  |  |
| 28 |  | Template selection for desktop | 1d? | 2021-05-06 | 2021-05-06 |  | 165d | start no earlier than 2021-05-06 |
| 29 |  | Template selection for Mobile | 1d? | 2021-05-07 | 2021-05-07 | 28 | 165d | start no earlier than 2021-05-07 |
| 30 | 3.9 | **Authorization Set up** | 5d? | 2021-05-10 | 2021-05-14 | 27 |  |  |
| 31 |  | Authorization includes email set up and permssion to the sharepoint for accessing project relateddocuments | 1d | 2021-05-10 | 2021-05-10 |  | 164d |  |
| 32 |  | Uploading Project Documentation | 1d? | 2021-05-11 | 2021-05-11 | 14 | 163d | start no earlier than 2021-05-11 |
| 33 |  | Creating Project Communication Process | 3d | 2021-05-12 | 2021-05-14 | 13 | 160d | start no earlier than 2021-05-12 |
| 34 | 3.10 | **Application Environment Set-up** | 7d? | 2021-05-17 | 2021-05-25 |  |  |  |
| 35 |  | Development Environment Set up | 2d | 2021-05-17 | 2021-05-18 |  | 153d |  |
| 36 |  | SIT Environment Set up | 2d | 2021-05-19 | 2021-05-20 | 35 | 153d | start no earlier than 2021-05-19 |
| 37 |  | Production Environment Set up | 1d? | 2021-05-21 | 2021-05-21 | 36 | 153d |  |
| 38 |  | UAT Environment Set up | 2d | 2021-05-24 | 2021-05-25 | 15, 37 | 153d | start no earlier than 2021-05-24 |
| 39 | 3.11 | **Requirement analysis of the customer** | 17d? | 2021-05-26 | 2021-06-18 |  |  |  |
| 40 |  | Getting an idea or overview of the website | 2d | 2021-05-26 | 2021-05-27 |  | 151d | finish no earlier than 2021-05-27 |
| 41 |  | Identification of Stakeholders | 1d? | 2021-05-28 | 2021-05-28 |  | 146d | start no earlier than 2021-05-28 |
| 42 |  | Gather requirements for the web application | 2d | 2021-06-01 | 2021-06-02 | 41 | 146d | start no earlier than 2021-06-01 |
| 43 |  | Conducting Meeting and Surveys | 1d | 2021-06-04 | 2021-06-04 | 42 | 145d | start no earlier than 2021-06-04 |
| 44 |  | Perform Stakeholder Analysis | 1d? | 2021-06-07 | 2021-06-07 | 43 | 145d | start no earlier than 2021-06-07 |
| 45 |  | Determing Solution Approach | 2d | 2021-06-08 | 2021-06-09 |  | 143d | start no earlier than 2021-06-08 |
| 46 |  | Finding new enhanced needs | 1d? | 2021-06-10 | 2021-06-10 |  | 139d | start no earlier than 2021-06-10 |
| 47 |  | Creation requirements draft | 1d? | 2021-06-11 | 2021-06-11 | 46 | 139d | start no earlier than 2021-06-11 |
| 48 |  | Document those requirements into Business Requirement Document and Funtional Requirement Document i.e. FRD & BRD | 2d | 2021-06-14 | 2021-06-15 | 47 | 139d | start no earlier than 2021-06-14 |
| 49 |  | Documented BRD and FRD | 0d | 2021-06-15 | 2021-06-15 | 48 | 139d | start no earlier than 2021-06-15 |
| 50 |  | Business Analysis Establishment | 1d? | 2021-06-16 | 2021-06-16 |  | 138d | start no earlier than 2021-06-16 |
| 51 |  | Preparation of Requirement Traceability Matrix | 2d | 2021-06-17 | 2021-06-18 |  | 136d | start no earlier than 2021-06-17 |
| 52 | 3.12 | **Project Risk Analysis** | 7d? | 2021-06-18 | 2021-06-28 |  |  |  |
| 53 |  | Analysis of risks involved | 2d | 2021-06-18 | 2021-06-21 |  | 130d |  |
| 54 |  | Registering the risks | 1d? | 2021-06-22 | 2021-06-22 | 53 | 130d | start no earlier than 2021-06-22 |
| 55 |  | Documenting the risks involved | 2d | 2021-06-23 | 2021-06-24 | 54 | 130d | start no earlier than 2021-06-23 |
| 56 |  | Development of WBS | 2d | 2021-06-25 | 2021-06-28 | 55 | 130d | start no earlier than 2021-06-25 |
| 57 |  | Work Breakdown Structure Development | 0d | 2021-06-28 | 2021-06-28 |  | 131d | start no earlier than 2021-06-28 |
| 58 |  | Project Planning Phase End | 0d | 2021-06-28 | 2021-06-28 |  | 131d | start no earlier than 2021-06-28 |
| 59 | 4 | **Project Execution** | 81d? | 2021-06-29 | 2021-10-20 |  |  |  |
| 60 | 4.1 | **Web Design Architure** | 8d? | 2021-06-29 | 2021-07-08 |  |  |  |
| 61 |  | Getting Server, memory and communication interfaces ready | 3d | 2021-06-29 | 2021-07-01 |  | 125d |  |
| 62 |  | Building functionality aspects | 2d | 2021-07-02 | 2021-07-05 | 61 | 125d | start no earlier than 2021-07-02 |
| 63 |  | Building visual appearance as User Interface design | 3d | 2021-07-06 | 2021-07-08 |  | 115d | start no earlier than 2021-07-06 |
| 64 | 4.2 | **Business Analysis** | 20d? | 2021-07-09 | 2021-08-05 |  |  |  |
| 65 |  | Organizing, verifying and validating the gathered requirements | 3d | 2021-07-09 | 2021-07-13 | 63 | 115d |  |
| 66 |  | Analysis of change requirements | 2d | 2021-07-14 | 2021-07-15 | 65 | 115d | start no earlier than 2021-07-14 |
| 67 |  | Translation of the business requirements into technicality for development purpose | 2d? | 2021-07-16 | 2021-07-19 | 66 | 115d | start no earlier than 2021-07-16 |
| 68 |  | Workshop sessions with vendors | 2d | 2021-07-20 | 2021-07-21 |  | 112d | start no earlier than 2021-07-20 |
| 69 |  | Use Case Diagrams | 1d? | 2021-07-22 | 2021-07-22 | 68 | 112d | start no earlier than 2021-07-22 |
| 70 |  | Conduct Unit Testing Activites | 2d | 2021-07-23 | 2021-07-26 |  | 110d | start no earlier than 2021-07-23 |

| ID | WBS | Task | Duration | Start | Finish | Predecessors | Total float | Constraint |
| --- | --- | --- | --- | --- | --- | --- | --- | --- |
| 71 |  | Performance Reporting and Progress tracking | 4d | 2021-07-27 | 2021-07-30 |  | 106d | start no earlier than 2021-07-27 |
| 72 |  | Working on Change Requests | 2d | 2021-08-02 | 2021-08-03 |  | 102d | start no earlier than 2021-08-02 |
| 73 |  | Updating the change documentation | 2d | 2021-08-04 | 2021-08-05 | 72 | 102d | start no earlier than 2021-08-04 |
| 74 | 4.3 | **Web application Development & Testing** | 53d? | 2021-08-06 | 2021-10-20 |  |  |  |
| 75 |  | Review of the requirements or features for development | 1d? | 2021-08-06 | 2021-08-06 |  | 86d |  |
| 76 |  | Coding or developing the requirements which meets the acceptance critieria | 5d | 2021-08-09 | 2021-08-13 | 75 | 86d | start no earlier than 2021-08-09 |
| 77 |  | Performing Unit Testing | 2d | 2021-08-16 | 2021-08-17 | 76 | 86d | finish no earlier than 2021-08-17 |
| 78 |  | Perform Integration Tesing | 2d | 2021-08-18 | 2021-08-19 | 77 | 86d | start no earlier than 2021-08-18 |
| 79 |  | Deploying the features into development envrionment and system integration test environment | 1d | 2021-08-20 | 2021-08-20 | 78 | 86d | start no earlier than 2021-08-20 |
| 80 |  | Testing the features in development environment | 1d? | 2021-08-23 | 2021-08-23 | 79 | 86d | start no earlier than 2021-08-23 |
| 81 |  | Debugging the application | 1d? | 2021-08-24 | 2021-08-24 | 80 | 89d | start no earlier than 2021-08-24 |
| 82 |  | Deployment of features into system integration test environment | 1d | 2021-08-25 | 2021-08-25 | 80 | 85d | start no earlier than 2021-08-25 |
| 83 |  | Integration of new features in the application | 3d | 2021-08-26 | 2021-08-30 | 82 | 85d | start no earlier than 2021-08-26 |
| 84 |  | Deployment Accomplished | 0d | 2021-08-30 | 2021-08-30 | 83 | 85d | start no earlier than 2021-08-30 |
| 85 |  | Test plan Review | 1d? | 2021-08-31 | 2021-08-31 |  | 73d | start no earlier than 2021-08-31 |
| 86 |  | Preparing the test plan | 3d | 2021-09-01 | 2021-09-03 | 85 | 73d | start no earlier than 2021-09-01 |
| 87 |  | Preparing test scenarios | 2d | 2021-09-07 | 2021-09-08 |  | 79d | start no earlier than 2021-09-07 |
| 88 |  | Preparing the test scripts as per organization template | 5d | 2021-09-09 | 2021-09-15 | 86 | 71d | start no earlier than 2021-09-09 |
| 89 |  | Executing the test scripts and updating the results i.e. pass or fail | 2d | 2021-09-16 | 2021-09-17 | 88 | 71d | start no earlier than 2021-09-16 |
| 90 |  | Test result documentation process | 1d? | 2021-09-20 | 2021-09-20 | 89 | 71d | start no earlier than 2021-09-20 |
| 91 |  | Loging defects found in the application with bug severirties & priorities | 2d | 2021-09-21 | 2021-09-22 |  | 66d | start no earlier than 2021-09-21 |
| 92 |  | Developers fix the issues | 2d | 2021-09-23 | 2021-09-24 | 91 | 66d | start no earlier than 2021-09-23 |
| 93 |  | Retesting is done | 1d? | 2021-09-27 | 2021-09-27 | 92 | 66d | start no earlier than 2021-09-27 |
| 94 |  | Regression testing on newly deployed features | 1d | 2021-09-28 | 2021-09-28 |  | 65d | start no earlier than 2021-09-28 |
| 95 |  | Application's functionality successful in SIT environment | 0d | 2021-09-28 | 2021-09-28 |  | 66d | start no earlier than 2021-09-28 |
| 96 |  | Secuity Based Testing | 1d? | 2021-09-29 | 2021-09-29 |  | 56d | start no earlier than 2021-09-29 |
| 97 |  | Stress Testing | 1d | 2021-09-30 | 2021-09-30 | 96 | 56d | start no earlier than 2021-09-30 |
| 98 |  | Performance Testing | 1d? | 2021-10-01 | 2021-10-01 | 97 | 61d | start no earlier than 2021-10-01 |
| 99 |  | Load Testing | 1d? | 2021-10-04 | 2021-10-04 | 98 | 61d | start no earlier than 2021-10-04 |
| 100 |  | Performing UAT and coording with business users | 2d | 2021-10-05 | 2021-10-06 | 97 | 54d | start no earlier than 2021-10-05 |
| 101 |  | Making changes before pre-production | 1d? | 2021-10-07 | 2021-10-07 |  | 58d | start no earlier than 2021-10-07 |
| 102 |  | Performing Pilot testing | 2d | 2021-10-08 | 2021-10-11 | 100 | 53d | start no earlier than 2021-10-08 |
| 103 |  | Training the users on the application usage | 3d | 2021-10-12 | 2021-10-14 | 102 | 53d | start no earlier than 2021-10-12 |
| 104 |  | Transfer of new database structures | 1d | 2021-10-15 | 2021-10-15 |  | 51d | start no earlier than 2021-10-15 |
| 105 |  | Database testing | 1d? | 2021-10-18 | 2021-10-18 | 104 | 51d | start no earlier than 2021-10-18 |
| 106 |  | Readiness Review of the application | 1d? | 2021-10-19 | 2021-10-19 |  | 50d | start no earlier than 2021-10-19 |
| 107 |  | Moving the application into production environment | 1d | 2021-10-20 | 2021-10-20 |  | 49d | start no earlier than 2021-10-20 |
| 108 |  | Project Execution Phase End | 0d | 2021-10-20 | 2021-10-20 |  | 50d | start no earlier than 2021-10-20 |
| 109 | 5 | **Project Monitoring & Controlling Phase** | 35d? | 2021-10-21 | 2021-12-10 |  |  |  |
| 110 | 5.1 | **Solution towards Application's issues** | 11d? | 2021-10-21 | 2021-11-04 |  |  |  |
| 111 |  | Monitoring key server resources for the purpose of load and usage | 2d | 2021-10-21 | 2021-10-22 |  | 43d |  |
| 112 |  | Monitoring the response and load time | 2d | 2021-10-25 | 2021-10-26 | 111 | 43d | start no earlier than 2021-10-25 |
| 113 |  | Monitoring version and configuration changes | 2d | 2021-10-27 | 2021-10-28 | 112 | 43d | start no earlier than 2021-10-27 |
| 114 |  | Controlling the scope of the deployed requirements | 2d | 2021-10-29 | 2021-11-01 |  | 41d | start no earlier than 2021-10-29 |
| 115 |  | Tracking the performance of the application | 2d | 2021-11-02 | 2021-11-03 |  | 38d | start no earlier than 2021-11-02 |
| 116 |  | Information and reporting on end user's issues in production | 1d? | 2021-11-04 | 2021-11-04 | 115 | 38d | start no earlier than 2021-11-04 |
| 117 | 5.2 | **Network traffic monitoring** | 5d? | 2021-11-05 | 2021-11-11 |  |  |  |
| 118 |  | Monitoring, tracing and analyzing traffic data once for all | 2d | 2021-11-05 | 2021-11-08 |  | 33d | start no earlier than 2021-11-05 |
| 119 |  | Identifying the major users of the network | 1d | 2021-11-09 | 2021-11-09 | 118 | 33d | finish no earlier than 2021-11-09 |
| 120 |  | Troubleshoot the issues | 1d? | 2021-11-10 | 2021-11-10 | 119 | 33d | start no earlier than 2021-11-10 |
| 121 |  | Transition support set up for users | 1d? | 2021-11-11 | 2021-11-11 | 120 | 33d | start no earlier than 2021-11-11 |
| 122 | 5.2 | **Monitoring the response time of servers** | 5d? | 2021-11-12 | 2021-11-18 |  |  |  |
| 123 |  | Checking the server response time with both physically and virtually | 2d | 2021-11-12 | 2021-11-15 |  | 29d |  |
| 124 |  | Reporting from Network and database Administration | 2d | 2021-11-16 | 2021-11-17 | 123 | 29d | start no earlier than 2021-11-16 |
| 125 |  | Isolating application Issues | 1d? | 2021-11-18 | 2021-11-18 |  | 28d | start no earlier than 2021-11-18 |
| 126 | 5.3 | **Identifying user feedback** | 4d? | 2021-11-19 | 2021-11-24 |  |  |  |
| 127 |  | Updates on the deployments | 1d? | 2021-11-19 | 2021-11-19 |  | 24d |  |
| 128 |  | Capturing and documenting issues in production | 2d | 2021-11-22 | 2021-11-23 | 127 | 24d | start no earlier than 2021-11-22 |
| 129 |  | Ensuring issues are resolved successfully | 1d | 2021-11-24 | 2021-11-24 | 128 | 24d | finish no earlier than 2021-11-24 |
| 130 | 5.4 | **Maintaince of the application** | 4d? | 2021-11-29 | 2021-12-02 |  |  |  |
| 131 |  | Minor Bug fixes for new versions | 1d | 2021-11-29 | 2021-11-29 |  | 20d |  |
| 132 |  | Updating new supporting frameworks | 1d? | 2021-11-30 | 2021-11-30 | 131 | 20d | start no earlier than 2021-11-30 |
| 133 |  | Inserting or Importing new data for enhancements | 1d | 2021-12-01 | 2021-12-01 | 132 | 20d | start no earlier than 2021-12-01 |
| 134 |  | Confirmation on the service level agreements | 1d? | 2021-12-02 | 2021-12-02 | 133 | 20d | start no earlier than 2021-12-02 |
| 135 | 5.5 | **Post production support** | 6d? | 2021-12-03 | 2021-12-10 |  |  |  |
| 136 |  | Retesting the new version changes | 1d? | 2021-12-03 | 2021-12-03 |  | 15d |  |
| 137 |  | Approval of new version changes | 1d? | 2021-12-06 | 2021-12-06 | 136 | 15d | start no earlier than 2021-12-06 |
| 138 |  | Version Approval | 0d | 2021-12-06 | 2021-12-06 | 137 | 15d | start no earlier than 2021-12-06 |
| 139 |  | Implementing critical changes | 1d? | 2021-12-07 | 2021-12-07 | 138 | 15d | start no earlier than 2021-12-07 |
| 140 |  | Regulatory maintainence and Compliances | 2d? | 2021-12-08 | 2021-12-09 | 139 | 15d | finish no earlier than 2021-12-09 |

| ID | WBS | Task | Duration | Start | Finish | Predecessors | Total float | Constraint |
| --- | --- | --- | --- | --- | --- | --- | --- | --- |
| 141 |  | Residual Error fixes | 1d? | 2021-12-10 | 2021-12-10 |  | 14d | start no earlier than 2021-12-10 |
| 142 | 5.6.7 | **Montly Status Meeting** | 154d | 2021-05-03 | 2021-12-08 |  |  |  |
| 143 |  | Montly Status Meeting 1 | 1d | 2021-05-10 | 2021-05-10 |  | 157d | start no earlier than 2021-05-08 |
| 144 |  | Montly Status Meeting 2 | 1d | 2021-06-08 | 2021-06-08 | 143 | 138d | start no earlier than 2021-06-08 |
| 145 |  | Montly Status Meeting 3 | 1d | 2021-07-08 | 2021-07-08 | 144 | 117d | start no earlier than 2021-07-08 |
| 146 |  | Montly Status Meeting 4 | 1d | 2021-08-09 | 2021-08-09 | 145 | 96d | start no earlier than 2021-08-08 |
| 147 |  | Montly Status Meeting 5 | 1d | 2021-09-08 | 2021-09-08 | 146 | 76d | start no earlier than 2021-09-08 |
| 148 |  | Montly Status Meeting 6 | 1d | 2021-10-08 | 2021-10-08 | 147 | 55d | start no earlier than 2021-10-08 |
| 149 |  | Montly Status Meeting 7 | 1d | 2021-11-08 | 2021-11-08 | 148 | 35d | start no earlier than 2021-11-08 |
| 150 |  | Montly Status Meeting 8 | 1d | 2021-12-08 | 2021-12-08 | 149 | 16d | start no earlier than 2021-12-08 |
| 151 |  | Project Monitoring & Controlling Phase End | 0d | 2021-12-10 | 2021-12-10 |  | 15d | start no earlier than 2021-12-10 |
| 152 | 6 | **Project Closing Phase** | 14d? | 2021-12-13 | 2021-12-31 |  |  |  |
| 153 | 6.1 | **Evaluation Reporting** | 5d? | 2021-12-13 | 2021-12-17 |  | 9d |  |
| 154 |  | Collection and Evaluation of performances of the application | 2d | 2021-12-13 | 2021-12-14 |  | 11d | start no earlier than 2021-12-13 |
| 155 |  | Formal Acceptability from the users | 1d? | 2021-12-15 | 2021-12-15 | 154 | 11d | start no earlier than 2021-12-15 |
| 156 |  | Lessons learnt document analysis | 2d | 2021-12-16 | 2021-12-17 |  | 9d | start no earlier than 2021-12-16 |
| 157 | 6.2 | **Benfit Analysis Reporting** | 2d? | 2021-12-20 | 2021-12-21 |  |  |  |
| 158 |  | Highlighting of web application features | 1d | 2021-12-20 | 2021-12-20 |  | 7d |  |
| 159 |  | Brief summary of final product or service | 1d | 2021-12-21 | 2021-12-21 | 158 | 7d | start no earlier than 2021-12-21 |
| 160 | 6.3 | **Project Status Reporting** | 7d? | 2021-12-22 | 2021-12-31 |  |  |  |
| 161 |  | Operational and Support documentation | 1d? | 2021-12-22 | 2021-12-22 |  | 3d |  |
| 162 |  | Phase closure documentation | 1d? | 2021-12-23 | 2021-12-23 | 161 | 3d |  |
| 163 |  | Scope, quality and objective reporting | 2d | 2021-12-27 | 2021-12-28 | 162 | 3d |  |
| 164 |  | Genrating Monthly and weekly status reports | 1d | 2021-12-29 | 2021-12-29 |  | 2d | start no earlier than 2021-12-29 |
| 165 |  | Successful Project Reporting | 0d | 2021-12-29 | 2021-12-29 |  | 3d | start no earlier than 2021-12-29 |
| 166 |  | Project Review Documentation | 1d? | 2021-12-30 | 2021-12-30 |  | 0d | start no earlier than 2021-12-30 |
| 167 |  | Release the project Resoures | 1d? | 2021-12-31 | 2021-12-31 | 166 | 0d | start no earlier than 2021-12-31 |
| 168 |  | Project Closing Phase End | 0d | 2021-12-31 | 2021-12-31 |  | 1d | start no earlier than 2021-12-31 |

## Version 2 (saved 2021-04-21, file pmgt699wbsresource-mpp)

Last finish stays 2021-12-31.

Added:

| ID | Task | Duration | Start | Finish | Predecessors | Constraint | Resources |
| --- | --- | --- | --- | --- | --- | --- | --- |
| 77 | Mobile application development | 2d | 2021-08-12 | 2021-08-13 |  | start no earlier than 2021-08-12 | Ashley Robertson; Ryan Williamson |
| 170 | **Contingency** | 71d? | 2021-09-20 | 2021-12-30 |  |  |  |
| 171 | Contingency #1 | 31d? | 2021-09-20 | 2021-11-01 |  | finish no earlier than 2021-11-01 |  |
| 172 | Contingency #2 | 5d? | 2021-11-02 | 2021-11-08 | 171 | finish no earlier than 2021-10-22 |  |
| 173 | Contingency #3 | 1d? | 2021-12-30 | 2021-12-30 | 172 | start no earlier than 2021-12-30 |  |

Changed:

| ID | Task | Start | Finish | Duration | Total float | Predecessors | Other |
| --- | --- | --- | --- | --- | --- | --- | --- |
| 1 | Online Retail Grocery Store website’s software development | 2021-04-05 → 2009-10-12 (-4193d) | 2021-12-31 → 2010-07-02 (-4200d) |  | 0d → 2995d |  | constraint start no earlier than 2021-04-05 → none |
| 3 | **Project Initiation** |  |  |  |  |  | resources none → Boniface Barrack; Naga Srinivas |
| 4 | Project Charter Review |  | 2021-04-06 → 2021-04-05 (-1d) | 2d? → 1d? | 174d → 185.69d |  | constraint finish no earlier than 2021-04-06 → none; resources none → Boniface Barrack; Naga Srinivas |
| 5 | Project proposal Evaluation |  | 2021-04-09 → 2021-04-07 (-2d) | 3d → 1d | 174d → 183.69d | 4 → 4FS-1d | resources none → Boniface Barrack; Naga Srinivas |
| 6 | Project Kick off Meeting |  |  | 1d → 0.31d | 174d → 180.69d | 5 → 5FS-1d | resources none → Boniface Barrack; Naga Srinivas |
| 7 | Project Vision and Mission Statement |  |  |  |  |  | resources none → Boniface Barrack |
| 8 | Defining Problem Statement |  |  | 1d? → 0.8d? | 182d → 182.2d |  | resources none → Boniface Barrack [62.5%]; Naga Srinivas [62.5%] |
| 9 | Onboarding of project resources |  |  |  | 172d → 177d | 6 → 6FS-1d | resources none → Boniface Barrack |
| 10 | Documentation of Project Charter | 2021-04-16 → 2021-04-15 (-1d) | 2021-04-20 → 2021-04-19 (-1d) |  | 172d → 177d | 9 → 9FS-1d | resources none → Boniface Barrack [91.7%]; Naga Srinivas [91.7%] |
| 11 | Signatures on Project Charter Team | 2021-04-21 → 2021-04-19 (-2d) | 2021-04-21 → 2021-04-19 (-2d) |  | 172d → 177d | 10 → 10FS-1d | resources none → Boniface Barrack [62.5%]; Naga Srinivas [62.5%] |
| 12 | Defining Responsibilties and goals | 2021-04-22 → 2021-04-20 (-2d) | 2021-04-22 → 2021-04-20 (-2d) |  | 172d → 176d | 11 → 11SS | resources none → Boniface Barrack; Naga Srinivas |
| 13 | Project Charter Document completion | 2021-04-23 → 2021-04-21 (-2d) | 2021-04-23 → 2021-04-21 (-2d) |  | 172d → 175d | 12 → 12FS-1d | resources none → Boniface Barrack; Naga Srinivas |
| 16 | **Project Planning** |  |  |  |  |  | resources none → Boniface Barrack; Naga Srinivas; Josephine Joel; Shaun Micheals |
| 17 | Review Project Documentation |  |  |  | 172d → 173d |  | resources none → Josephine Joel; Naga Srinivas; Shaun Micheals |
| 18 | Create a PMP Draft Template |  |  |  |  | 17 → 17FF | resources none → Boniface Barrack; Naga Srinivas |
| 19 | Review the draft PMP with project team |  |  |  |  | 17, 18 → 17, 18FF+1d | resources none → Boniface Barrack; Naga Srinivas |
| 20 | Review/Approve PMP with Project Sponsor |  |  |  |  |  | resources none → Boniface Barrack; Naga Srinivas |
| 21 | PMP Approval |  |  |  | 171d → 172d | 20 → 20SF |  |
| 22 | **Tool and Technology Selection** | 2021-04-30 → 2021-04-26 (-4d) |  | 2d? → 6d? | none → 169d |  | resources none → Shaun Micheals |
| 23 | MS SQL | 2021-04-30 → 2021-04-26 (-4d) | 2021-04-30 → 2021-04-26 (-4d) |  | 169d → 174d |  | resources none → Shaun Micheals; Boniface Barrack |
| 24 | Dot Net Technology |  |  |  |  | 23 → 23SF | resources none → Shaun Micheals; Boniface Barrack |
| 25 | License Approval on Tool and Technology |  |  |  |  |  | resources none → Boniface Barrack; Naga Srinivas |
| 26 | Development of Organizational Chart which includes who reports to whom |  |  |  |  |  | resources none → Josephine Joel; Naga Srinivas |
| 27 | **Template selection of Website** |  | 2021-05-07 → 2021-05-10 (+3d) | 2d? → 3d? | none → 160d |  | resources none → Vendor [0.1%] |
| 28 | Template selection for desktop |  |  |  | 165d → 160d |  | resources none → Vendor [0.1%]; Boniface Barrack |
| 29 | Template selection for Mobile | 2021-05-07 → 2021-05-10 (+3d) | 2021-05-07 → 2021-05-10 (+3d) |  | 165d → 160d | 28 → 28FS+1d | resources none → Vendor [0.1%]; Boniface Barrack |
| 30 | **Authorization Set up** | 2021-05-10 → 2021-05-12 (+2d) |  | 5d? → 3d? | none → 160d | 27 → 27FS+1d |  |
| 31 | Authorization includes email set up and permssion to the sharepoint for accessing project relateddocuments | 2021-05-10 → 2021-05-12 (+2d) | 2021-05-10 → 2021-05-12 (+2d) |  | 164d → 162d |  | resources none → Boniface Barrack |
| 32 | Uploading Project Documentation | 2021-05-11 → 2021-05-12 (+1d) | 2021-05-11 → 2021-05-12 (+1d) |  | 163d → 162d | 14 → 14SS-1d | resources none → Naga Srinivas |
| 33 | Creating Project Communication Process |  |  |  |  | 13 → 13FS-1d | resources none → Naga Srinivas |
| 34 | **Application Environment Set-up** | 2021-05-17 → 2021-04-26 (-21d) | 2021-05-25 → 2021-05-27 (+2d) | 7d? → 24d? | none → 151d |  |  |
| 35 | Development Environment Set up | 2021-05-17 → 2021-04-26 (-21d) | 2021-05-18 → 2021-04-27 (-21d) |  | 153d → 165d |  | resources none → Ryan Williamson; Shaun Micheals |
| 36 | SIT Environment Set up |  |  |  | 153d → 151d | 35 → 35FS+1d | resources none → Ryan Williamson; Shaun Micheals |
| 37 | Production Environment Set up | 2021-05-21 → 2021-05-24 (+3d) | 2021-05-21 → 2021-05-24 (+3d) |  | 153d → 151d | 36 → 36FS+1d | resources none → Ryan Williamson; Shaun Micheals |
| 38 | UAT Environment Set up | 2021-05-24 → 2021-05-26 (+2d) | 2021-05-25 → 2021-05-27 (+2d) |  | 153d → 151d | 15, 37 → 15FS-1d, 37FS+1d | resources none → Ryan Williamson; Shaun Micheals |
| 39 | **Requirement analysis of the customer** |  |  |  | none → 136d |  | resources none → Josephine Joel |
| 40 | Getting an idea or overview of the website |  |  |  |  |  | resources none → Josephine Joel |
| 41 | Identification of Stakeholders |  |  |  | 146d → 145d |  | resources none → Josephine Joel |
| 42 | Gather requirements for the web application |  |  |  | 146d → 144d | 41 → 41FS-1d | resources none → Josephine Joel |
| 43 | Conducting Meeting and Surveys |  |  |  | 145d → 144d | 42 → 42FS+1d | resources none → Josephine Joel |
| 44 | Perform Stakeholder Analysis | 2021-06-07 → 2021-06-08 (+1d) | 2021-06-07 → 2021-06-08 (+1d) |  | 145d → 144d | 43 → 43FS+1d | resources none → Josephine Joel |
| 45 | Determing Solution Approach |  |  |  |  |  | resources none → Josephine Joel |
| 46 | Finding new enhanced needs |  |  |  |  |  | resources none → Josephine Joel |
| 47 | Creation requirements draft |  |  |  | 139d → 138d | 46 → 46SS-1d | resources none → Josephine Joel |
| 48 | Document those requirements into Business Requirement Document and Funtional Requirement Document i.e. FRD & BRD | 2021-06-14 → 2021-06-15 (+1d) | 2021-06-15 → 2021-06-16 (+1d) |  | 139d → 138d | 47 → 47FS+1d | resources none → Josephine Joel |
| 49 | Documented BRD and FRD | 2021-06-15 → 2021-06-16 (+1d) | 2021-06-15 → 2021-06-16 (+1d) |  |  | 48 → 48FS-1d |  |
| 50 | Business Analysis Establishment |  |  |  |  |  | resources none → Josephine Joel |
| 51 | Preparation of Requirement Traceability Matrix |  |  |  |  |  | resources none → Josephine Joel |
| 52 | **Project Risk Analysis** | 2021-06-18 → 2021-04-26 (-53d) | 2021-06-28 → 2021-06-30 (+2d) | 7d? → 47d? | none → 128d |  |  |
| 53 | Analysis of risks involved | 2021-06-18 → 2021-04-26 (-53d) | 2021-06-21 → 2021-04-27 (-55d) |  | 130d → 165d |  | resources none → Naga Srinivas; Shaun Micheals |
| 54 | Registering the risks |  |  |  | 130d → 128d | 53 → 53FS+1d | resources none → Naga Srinivas |
| 55 | Documenting the risks involved | 2021-06-23 → 2021-06-24 (+1d) | 2021-06-24 → 2021-06-25 (+1d) |  | 130d → 128d | 54 → 54FS+1d | resources none → Josephine Joel; Naga Srinivas |
| 56 | Development of WBS | 2021-06-25 → 2021-06-29 (+4d) | 2021-06-28 → 2021-06-30 (+2d) |  | 130d → 128d | 55 → 55FS+1d | resources none → Naga Srinivas; Boniface Barrack |
| 57 | Work Breakdown Structure Development | 2021-06-28 → 2021-06-30 (+2d) | 2021-06-28 → 2021-06-30 (+2d) |  | 131d → 129d |  | constraint start no earlier than 2021-06-28 → start no earlier than 2021-06-30 |
| 58 | Project Planning Phase End | 2021-06-28 → 2021-06-30 (+2d) | 2021-06-28 → 2021-06-30 (+2d) |  | 131d → 129d |  | constraint start no earlier than 2021-06-28 → start no earlier than 2021-06-30 |
| 59 | **Project Execution** | 2021-06-29 → 2021-07-01 (+2d) | 2021-10-20 → 2021-10-22 (+2d) |  |  |  |  |
| 60 | **Web Design Architure** | 2021-06-29 → 2021-07-01 (+2d) |  | 8d? → 6d | none → -50d |  |  |
| 61 | Getting Server, memory and communication interfaces ready | 2021-06-29 → 2021-07-01 (+2d) | 2021-07-01 → 2021-07-05 (+4d) |  | 125d → -46d |  | resources none → Shaun Micheals |
| 62 | Building functionality aspects |  |  |  | 125d → -46d | 61 → 61FF-1d | resources none → Shaun Micheals; Ryan Williamson |
| 63 | Building visual appearance as User Interface design |  |  |  | 115d → -53d |  | resources none → Shaun Micheals |
| 64 | **Business Analysis** | 2021-07-09 → 2021-07-08 (-1d) |  | 20d? → 21d? | none → -69d |  |  |
| 65 | Organizing, verifying and validating the gathered requirements | 2021-07-09 → 2021-07-08 (-1d) | 2021-07-13 → 2021-07-12 (-1d) |  | 115d → -53d | 63 → 63FS-1d | resources none → Josephine Joel |
| 66 | Analysis of change requirements |  |  |  | 115d → -55d | 65 → 65FS-1d | resources none → Josephine Joel |
| 67 | Translation of the business requirements into technicality for development purpose |  |  |  | 115d → -56d | 66 → 66FS-1d | resources none → Josephine Joel |
| 68 | Workshop sessions with vendors |  |  |  | 112d → -59d |  | resources none → Josephine Joel |
| 69 | Use Case Diagrams |  |  |  | 112d → -59d |  | resources none → Josephine Joel |
| 70 | Conduct Unit Testing Activites |  |  |  | 110d → -61d |  | resources none → Josephine Joel |
| 71 | Performance Reporting and Progress tracking |  |  |  | 106d → -65d |  | resources none → Josephine Joel |
| 72 | Working on Change Requests |  |  |  | 102d → -67d |  | resources none → Josephine Joel |
| 73 | Updating the change documentation |  |  |  | 102d → -69d | 72 → 72SF+1d | resources none → Josephine Joel |

| ID | Task | Start | Finish | Duration | Total float | Predecessors | Other |
| --- | --- | --- | --- | --- | --- | --- | --- |
| 74 | **Web application Development & Testing** | 2021-08-06 → 2021-07-01 (-36d) |  | 53d? → 78d? | none → -121d |  |  |
| 75 | Review of the requirements or features for development | 2021-08-06 → 2021-07-01 (-36d) | 2021-08-06 → 2021-07-01 (-36d) |  | 86d → -58d |  | resources none → Ashley Robertson; Ryan Williamson |
| 76 | Coding or developing the requirements which meets the acceptance critieria |  | 2021-08-13 → 2021-08-11 (-2d) | 5d → 3d | 86d → -83d | 75 → 75FS+1d | resources none → Ashley Robertson; Ryan Williamson |
| 78 | Performing Unit Testing |  |  |  | 86d → -86d | 76 → 76FS-1d | resources none → Ashley Robertson |
| 79 | Perform Integration Tesing |  |  |  | 86d → -87d | 78 → 78FS-1d | resources none → Ryan Williamson |
| 80 | Deploying the features into development envrionment and system integration test environment |  |  |  | 86d → -88d | 79 → 79FS-1d | resources none → Ryan Williamson |
| 81 | Testing the features in development environment | 2021-08-23 → 2021-08-24 (+1d) | 2021-08-23 → 2021-08-24 (+1d) |  | 86d → -88d | 80 → 80FS+1d | resources none → Ashley Robertson; Diana James; Ryan Williamson |
| 82 | Debugging the application |  |  |  | 89d → -82d | 81 → 81FS-1d | resources none → Ashley Robertson; Ryan Williamson |
| 83 | Deployment of features into system integration test environment |  |  |  | 85d → -88d |  | resources none → Ryan Williamson |
| 84 | Integration of new features in the application | 2021-08-26 → 2021-08-27 (+1d) | 2021-08-30 → 2021-08-31 (+1d) |  | 85d → -88d | 83 → 83FS+1d | resources none → Ashley Robertson; Ryan Williamson |
| 85 | Deployment Accomplished | 2021-08-30 → 2021-09-01 (+2d) | 2021-08-30 → 2021-09-01 (+2d) |  | 85d → -88d | 84 → 84FS+1d |  |
| 86 | Test plan Review |  |  |  | 73d → -102d |  | resources none → Diana James |
| 87 | Preparing the test plan | 2021-09-01 → 2021-09-02 (+1d) | 2021-09-03 → 2021-09-07 (+4d) |  | 73d → -102d | 86 → 86FS+1d | resources none → Diana James |
| 88 | Preparing test scenarios |  |  |  | 79d → -92d |  | resources none → Diana James |
| 89 | Preparing the test scripts as per organization template |  |  |  | 71d → -102d | 87 → 87FS+1d | resources none → Diana James |
| 90 | Executing the test scripts and updating the results i.e. pass or fail | 2021-09-16 → 2021-09-17 (+1d) | 2021-09-17 → 2021-09-20 (+3d) |  | 71d → -102d | 89 → 89FS+1d | resources none → Diana James |
| 91 | Test result documentation process | 2021-09-20 → 2021-09-22 (+2d) | 2021-09-20 → 2021-09-22 (+2d) |  | 71d → -102d | 90 → 90FS+1d | resources none → Diana James |
| 92 | Logging defects found in the application with bug severirties & priorities |  |  |  | 66d → -107d |  | was named Loging defects found in the application with bug severirties & priorities; resources none → Diana James |
| 93 | Developers fix the issues | 2021-09-23 → 2021-09-24 (+1d) | 2021-09-24 → 2021-09-27 (+3d) |  | 66d → -107d | 92 → 92FS+1d | resources none → Ashley Robertson; Ryan Williamson |
| 94 | Retesting is done | 2021-09-27 → 2021-09-29 (+2d) | 2021-09-27 → 2021-09-29 (+2d) |  | 66d → -107d | 93 → 93FS+1d | resources none → Diana James |
| 95 | Regression testing on newly deployed features |  |  |  | 65d → -106d |  | resources none → Diana James |
| 97 | Secuity Based Testing |  |  |  | 56d → -115d |  | resources none → Diana James |
| 98 | Stress Testing | 2021-09-30 → 2021-10-01 (+1d) | 2021-09-30 → 2021-10-01 (+1d) |  | 56d → -115d | 97 → 97FS+1d | resources none → Diana James |
| 99 | Performance Testing | 2021-10-01 → 2021-10-06 (+5d) | 2021-10-01 → 2021-10-06 (+5d) |  | 61d → -112d | 98 → 98FS+2d | resources none → Diana James |
| 100 | Load Testing | 2021-10-04 → 2021-10-06 (+2d) | 2021-10-04 → 2021-10-06 (+2d) |  | 61d → -112d | 99 → 99FS-1d | resources none → Diana James |
| 101 | Performing UAT and coording with business users |  |  |  | 54d → -117d | 98 → 98FS-1d | resources none → Diana James; Josephine Joel |
| 102 | Making changes before pre-production |  |  |  | 58d → -113d |  | resources none → Ryan Williamson |
| 103 | Performing Pilot testing |  |  |  | 53d → -119d | 101 → 101FS-1d | resources none → Diana James; Josephine Joel |
| 104 | Training the users on the application usage | 2021-10-12 → 2021-10-13 (+1d) | 2021-10-14 → 2021-10-15 (+1d) |  | 53d → -119d | 103 → 103FS+1d | resources none → Josephine Joel; Naga Srinivas |
| 105 | Transfer of new database structures |  |  |  | 51d → -121d |  | resources none → Shaun Micheals |
| 106 | Database testing | 2021-10-18 → 2021-10-19 (+1d) | 2021-10-18 → 2021-10-19 (+1d) |  | 51d → -121d | 105 → 105FS+1d | resources none → Shaun Micheals |
| 107 | Readiness Review of the application |  |  |  | 50d → -121d |  | resources none → Josephine Joel; Naga Srinivas; Shaun Micheals |
| 108 | Moving the application into production environment | 2021-10-20 → 2021-10-15 (-5d) | 2021-10-20 → 2021-10-18 (-2d) |  | 49d → -119d | none → 107SF-1d | constraint start no earlier than 2021-10-20 → as late as possible; resources none → Ryan Williamson |
| 110 | **Project Monitoring & Controlling Phase** |  |  |  |  | none → 59FS+1d |  |
| 112 | Monitoring key server resources for the purpose of load and usage |  |  |  |  |  | resources none → Ashley Robertson; Ryan Williamson |
| 113 | Monitoring the response and load time |  |  |  | 43d → 42d | 112 → 112FS-1d | resources none → Diana James; Josephine Joel |
| 114 | Monitoring version and configuration changes | 2021-10-27 → 2021-10-28 (+1d) | 2021-10-28 → 2021-10-29 (+1d) |  | 43d → 42d | 113 → 113FS+1d | resources none → Diana James |
| 115 | Controlling the scope of the deployed requirements |  |  |  |  |  | resources none → Shaun Micheals |
| 116 | Tracking the performance of the application |  |  |  | 38d → 37d |  | resources none → Naga Srinivas; Shaun Micheals |
| 117 | Information and reporting on end user's issues in production | 2021-11-04 → 2021-11-05 (+1d) | 2021-11-04 → 2021-11-05 (+1d) |  | 38d → 37d | 116 → 116FS+1d | resources none → Josephine Joel |
| 119 | Monitoring, tracing and analyzing traffic data once for all |  |  |  | 33d → 34d |  | resources none → Josephine Joel; Shaun Micheals |
| 120 | Identifying the major users of the network |  |  |  |  | 119 → 119FS-1d | resources none → Josephine Joel; Shaun Micheals |
| 121 | Troubleshoot the issues | 2021-11-10 → 2021-11-11 (+1d) | 2021-11-10 → 2021-11-11 (+1d) |  |  | 120 → 120FS+1d | resources none → Ryan Williamson; Ashley Robertson |
| 122 | Transition support set up for users |  |  |  |  | 121 → 121FS-1d | resources none → Shaun Micheals |
| 124 | Checking the server response time with both physically and virtually |  |  |  | 29d → 30d |  | resources none → Josephine Joel; Ryan Williamson |
| 125 | Reporting from Network and database Administration |  |  |  |  | 124 → 124FS-1d | resources none → Shaun Micheals |
| 126 | Isolating application Issues |  |  |  |  |  | resources none → Ashley Robertson; Ryan Williamson |
| 128 | Updates on the deployments |  |  |  |  |  | resources none → Josephine Joel; Naga Srinivas |
| 129 | Capturing and documenting issues in production | 2021-11-22 → 2021-11-23 (+1d) | 2021-11-23 → 2021-11-24 (+1d) |  |  | 128 → 128FS+1d | resources none → Josephine Joel |
| 130 | Ensuring issues are resolved successfully |  |  |  |  | 129 → 129FS-1d | resources none → Ryan Williamson; Naga Srinivas |
| 133 | Updating new supporting frameworks |  |  |  |  |  | resources none → Shaun Micheals |
| 134 | Inserting or Importing new data for enhancements |  |  |  |  |  | resources none → Shaun Micheals |
| 135 | Confirmation on the service level agreements |  |  |  |  |  | resources none → Boniface Barrack; Naga Srinivas |
| 137 | Retesting the new version changes |  |  |  |  |  | resources none → Diana James |
| 138 | Approval of new version changes |  |  |  |  |  | resources none → Boniface Barrack |
| 140 | Implementing critical changes |  |  |  |  |  | resources none → Ryan Williamson |
| 141 | Regulatory maintainence and Compliances |  |  |  |  |  | resources none → Shaun Micheals |
| 142 | Residual Error fixes |  |  |  |  |  | resources none → Ashley Robertson |
| 143 | **Montly Status Meeting** |  | 2021-12-08 → 2021-12-03 (-5d) | 154d → 151d |  |  |  |
| 144 | Montly Status Meeting 1 | 2021-05-10 → 2021-05-03 (-7d) | 2021-05-10 → 2021-05-03 (-7d) |  | 157d → 162d |  | constraint start no earlier than 2021-05-08 → none; resources none → Boniface Barrack |
| 145 | Montly Status Meeting 2 | 2021-06-08 → 2021-05-04 (-35d) | 2021-06-08 → 2021-05-04 (-35d) |  | 138d → 162d |  | constraint start no earlier than 2021-06-08 → none; resources none → Boniface Barrack |
| 146 | Montly Status Meeting 3 | 2021-07-08 → 2021-05-05 (-64d) | 2021-07-08 → 2021-05-05 (-64d) |  | 117d → 162d |  | constraint start no earlier than 2021-07-08 → none; resources none → Boniface Barrack |
| 147 | Montly Status Meeting 4 | 2021-08-09 → 2021-05-06 (-95d) | 2021-08-09 → 2021-05-06 (-95d) |  | 96d → 162d |  | constraint start no earlier than 2021-08-08 → finish no later than 2021-12-27; resources none → Boniface Barrack |
| 148 | Montly Status Meeting 5 |  |  |  |  |  | resources none → Boniface Barrack |
| 149 | Montly Status Meeting 6 | 2021-10-08 → 2021-12-29 (+82d) | 2021-10-08 → 2021-12-29 (+82d) |  | 55d → 0d |  | constraint start no earlier than 2021-10-08 → as late as possible; resources none → Boniface Barrack |
| 150 | Montly Status Meeting 7 | 2021-11-08 → 2021-12-30 (+52d) | 2021-11-08 → 2021-12-30 (+52d) |  | 35d → 0d | 149 → 149, 154FS-1d, 158 | resources none → Boniface Barrack |
| 151 | Montly Status Meeting 8 | 2021-12-08 → 2021-12-31 (+23d) | 2021-12-08 → 2021-12-31 (+23d) |  | 16d → 0d |  | resources none → Boniface Barrack |
| 155 | Collection and Evaluation of performances of the application |  |  |  |  |  | resources none → Boniface Barrack |
| 156 | Formal Acceptability from the users |  |  |  | 11d → 10d | 155 → 155FS-1d | resources none → Boniface Barrack; Naga Srinivas |
| 157 | Lessons learnt document analysis |  |  |  | 9d → 8d |  | resources none → Naga Srinivas |

| ID | Task | Start | Finish | Duration | Total float | Predecessors | Other |
| --- | --- | --- | --- | --- | --- | --- | --- |
| 158 | **Benfit Analysis Reporting** | 2021-12-20 → 2021-12-13 (-7d) |  | 2d? → 7d | none → 5d |  |  |
| 159 | Highlighting of web application features | 2021-12-20 → 2021-12-13 (-7d) | 2021-12-20 → 2021-12-13 (-7d) |  | 7d → 11d |  | resources none → Josephine Joel |
| 160 | Brief summary of final product or service |  |  |  | 7d → 5d | 159 → 159FF | resources none → Naga Srinivas |
| 161 | **Project Status Reporting** | 2021-12-22 → 2021-12-13 (-9d) |  | 7d? → 14d? | none → 0d |  |  |
| 162 | Operational and Support documentation | 2021-12-22 → 2021-12-13 (-9d) | 2021-12-22 → 2021-12-13 (-9d) |  | 3d → 10d |  | resources none → Naga Srinivas; Shaun Micheals |
| 163 | Phase closure documentation | 2021-12-23 → 2021-12-15 (-8d) | 2021-12-23 → 2021-12-15 (-8d) |  | 3d → 10d | 162 → 162FS+1d | resources none → Naga Srinivas |
| 164 | Scope, quality and objective reporting | 2021-12-27 → 2021-12-15 (-12d) | 2021-12-28 → 2021-12-16 (-12d) |  | 3d → 10d | 163 → 163FS-1d | resources none → Naga Srinivas |
| 165 | Genrating Monthly and weekly status reports |  |  |  |  |  | resources none → Naga Srinivas |
| 166 | Successful Project Reporting |  |  |  |  |  | resources none → Naga Srinivas |
| 167 | Project Review Documentation |  |  |  | 0d → 1d |  | resources none → Boniface Barrack |
| 168 | Release the project Resoures |  |  |  |  | 167 → 167FS-1d | resources none → Boniface Barrack |

## Version 3 (data date 2021-04-22, saved 2021-05-31, file pmgt699wbsmid-termassignment-copy-mpp)

Last finish 2021-12-31 → 2022-01-20 (+20d).

Added:

| ID | Task | Duration | Start | Finish | Constraint | Resources |
| --- | --- | --- | --- | --- | --- | --- |
| 163 | Execution of new change features | 8d | 2021-12-30 | 2022-01-10 | start no earlier than 2021-12-30 |  |
| 174 | **Project Change Requests** | 14d? | 2021-09-22 | 2021-10-11 |  |  |
| 175 | Adding and modification in new design features | 14d? | 2021-09-22 | 2021-10-11 |  | Shaun Micheals |

Removed: 1 Online Retail Grocery Store website’s software development

Changed:

| ID | Task | Start | Finish | Duration | Total float | Other |
| --- | --- | --- | --- | --- | --- | --- |
| 1 | **Online Retail Grocery Store website’s software development** |  |  |  |  | was named Project Management; baseline start none → 2021-04-05; baseline finish none → 2021-12-31 |
| 2 | **Project Initiation** |  |  |  |  | resources Boniface Barrack; Naga Srinivas → none; baseline start none → 2021-04-05; baseline finish none → 2021-07-01 |
| 3 | Project Charter Review |  |  |  | 185.69d → 193.38d | resources Boniface Barrack; Naga Srinivas → Desktops [50%]; Diana James [50%]; baseline start none → 2021-04-05; baseline finish none → 2021-04-05 |
| 4 | Project proposal Evaluation |  | 2021-04-07 → 2021-04-08 (+1d) | 1d → 2d | 183.69d → 191.38d | resources Boniface Barrack; Naga Srinivas → Microsoft [0.1%]; Ryan Williamson [50%]; baseline start none → 2021-04-07; baseline finish none → 2021-04-08 |
| 5 | Project Kick off Meeting |  |  | 0.31d → 0.62d | 180.69d → 189.38d | resources Boniface Barrack; Naga Srinivas → Printers [50%]; Ashley Robertson; baseline start none → 2021-04-12; baseline finish none → 2021-04-12 |
| 6 | Project Vision and Mission Statement |  | 2021-04-13 → 2021-04-15 (+2d) | 1d? → 2.66d? | 183d → 195.34d | resources Boniface Barrack → Boniface Barrack [50%]; Naga Srinivas [50%]; baseline start none → 2021-04-13; baseline finish none → 2021-04-15 |
| 7 | Defining Problem Statement |  | 2021-04-14 → 2021-04-19 (+5d) |  | 182.2d → 193.2d | resources Boniface Barrack [62.5%]; Naga Srinivas [62.5%] → Naga Srinivas [62.5%]; Desktops; Furniture; Laptops; Microsoft [0.1%]; Federal Credit Union [0.1%]; baseline start none → 2021-04-14; baseline finish none → 2021-04-19 |
| 8 | Onboarding of project resources |  | 2021-04-15 → 2021-04-16 (+1d) | 1d? → 2d? | 177d → 186d | resources Boniface Barrack → Boniface Barrack [50%]; Naga Srinivas [50%]; Desktops; Furniture; Laptops; Microsoft [0.1%]; baseline start none → 2021-04-15; baseline finish none → 2021-04-16 |
| 9 | Documentation of Project Charter | 2021-04-15 → 2021-04-16 (+1d) | 2021-04-19 → 2021-04-20 (+1d) |  | 177d → 186d | resources Boniface Barrack [91.7%]; Naga Srinivas [91.7%] → Naga Srinivas [91.7%]; Desktops; Furniture; Laptops; Microsoft [0.1%]; Ryan Williamson; State of Ohio [0.1%]; Vendor [0.1%]; baseline start none → 2021-04-16; baseline finish none → 2021-04-20 |
| 10 | Signatures on Project Charter Team | 2021-04-19 → 2021-04-20 (+1d) | 2021-04-19 → 2021-04-21 (+2d) | 1d? → 2d? | 177d → 186d | baseline start none → 2021-04-20; baseline finish none → 2021-04-21 |
| 11 | Defining Responsibilties and goals | 2021-04-20 → 2021-04-22 (+2d) | 2021-04-20 → 2021-04-22 (+2d) |  | 176d → 186d | resources Boniface Barrack; Naga Srinivas → Naga Srinivas; baseline start none → 2021-04-22; baseline finish none → 2021-04-22 |
| 12 | Project Charter Document completion | 2021-04-21 → 2021-04-22 (+1d) | 2021-04-21 → 2021-04-23 (+2d) | 1d? → 2d? | 175d → 186d | baseline start none → 2021-04-22; baseline finish none → 2021-04-23 |
| 13 | Project Charter Approved |  |  |  | 176d → 190d | resources none → State of Ohio; baseline start none → 2021-04-23; baseline finish none → 2021-04-23 |
| 14 | Project Initiation Phase End |  |  |  | 175d → 189d | baseline start none → 2021-04-23; baseline finish none → 2021-04-23 |
| 15 | **Project Planning** |  |  |  |  | resources Boniface Barrack; Naga Srinivas; Josephine Joel; Shaun Micheals → none; baseline start none → 2021-04-26; baseline finish none → 2021-06-28 |
| 16 | Review Project Documentation |  | 2021-04-26 → 2021-04-30 (+4d) | 1d? → 0d? | 173d → 179d | resources Josephine Joel; Naga Srinivas; Shaun Micheals → Naga Srinivas; Desktops; State of Ohio [0.1%]; baseline start none → 2021-04-26; baseline finish none → 2021-04-30 |
| 17 | Create a PMP Draft Template | 2021-04-27 → 2021-04-29 (+2d) | 2021-04-27 → 2021-04-30 (+3d) | 1d? → 2d? | 172d → 182.33d | resources Boniface Barrack; Naga Srinivas → Naga Srinivas [50%]; Desktops; Furniture; Laptops; Microsoft [0.1%]; Printers; Diana James; baseline start none → 2021-04-29; baseline finish none → 2021-04-30 |
| 18 | Review the draft PMP with project team | 2021-04-28 → 2021-05-03 (+5d) | 2021-04-28 → 2021-05-10 (+12d) | 1d? → 2.83d? | 172d → 178.33d | resources Boniface Barrack; Naga Srinivas → Boniface Barrack [50%]; Naga Srinivas [50%]; Furniture; Laptops; Microsoft [0.1%]; Vendor [0.1%]; baseline start none → 2021-05-03; baseline finish none → 2021-05-10 |
| 19 | Review/Approve PMP with Project Sponsor |  | 2021-04-29 → 2021-05-04 (+5d) | 1d? → 2d? | 171d → 182.33d | baseline start none → 2021-04-29; baseline finish none → 2021-05-04 |
| 20 | PMP Approval |  |  |  | 172d → 186d | resources none → State of Ohio; baseline start none → 2021-04-29; baseline finish none → 2021-04-29 |
| 21 | **Tool and Technology Selection** | 2021-04-26 → 2021-04-30 (+4d) | 2021-05-03 → 2021-05-11 (+8d) | 6d? → 7.67d? | 169d → 177.33d | resources Shaun Micheals → none; baseline start none → 2021-04-30; baseline finish none → 2021-05-11 |
| 22 | MS SQL | 2021-04-26 → 2021-04-30 (+4d) | 2021-04-26 → 2021-05-03 (+7d) |  | 174d → 183d | resources Shaun Micheals; Boniface Barrack → Shaun Micheals; Desktops; Laptops; Microsoft [0.1%]; baseline start none → 2021-04-30; baseline finish none → 2021-05-03 |
| 23 | Dot Net Technology |  | 2021-05-03 → 2021-05-11 (+8d) | 1d? → 1.67d? | 169d → 177.33d | baseline start none → 2021-05-03; baseline finish none → 2021-05-11 |
| 24 | License Approval on Tool and Technology |  |  |  | 170d → 184d | baseline start none → 2021-05-03; baseline finish none → 2021-05-03 |
| 25 | Development of Organizational Chart which includes who reports to whom |  | 2021-05-05 → 2021-05-10 (+5d) | 2d? → 4d? | 167d → 178.17d | baseline start none → 2021-05-04; baseline finish none → 2021-05-10 |
| 26 | **Template selection of Website** |  |  |  | 160d → none | resources Vendor [0.1%] → none; baseline start none → 2021-05-06; baseline finish none → 2021-05-10 |
| 27 | Template selection for desktop |  | 2021-05-06 → 2021-05-10 (+4d) | 1d? → 2d? | 160d → 165.67d | resources Vendor [0.1%]; Boniface Barrack → Vendor [0.1%]; Boniface Barrack; Desktops; Furniture; Laptops; Shaun Micheals; baseline start none → 2021-05-06; baseline finish none → 2021-05-10 |
| 28 | Template selection for Mobile | 2021-05-10 → 2021-05-11 (+1d) | 2021-05-10 → 2021-05-27 (+17d) |  | 160d → 165.67d | baseline start none → 2021-05-11; baseline finish none → 2021-05-27 |
| 29 | **Authorization Set up** |  | 2021-05-14 → 2021-05-18 (+4d) | 3d? → 4.67d? | 160d → 172.33d | baseline start none → 2021-05-12; baseline finish none → 2021-05-18 |
| 30 | Authorization includes email set up and permssion to the sharepoint for accessing project relateddocuments | 2021-05-12 → 2021-05-17 (+5d) | 2021-05-12 → 2021-05-18 (+6d) |  | 162d → 172.33d | baseline start none → 2021-05-17; baseline finish none → 2021-05-18 |
| 31 | Uploading Project Documentation |  |  |  | 162d → 176d | baseline start none → 2021-05-12; baseline finish none → 2021-05-12 |
| 32 | Creating Project Communication Process |  | 2021-05-14 → 2021-05-17 (+3d) | 3d → 4d | 160d → 173d | resources Naga Srinivas → Naga Srinivas; Boniface Barrack; Diana James; Furniture; Josephine Joel; Laptops; Microsoft [0.1%]; State of Ohio [0.1%]; baseline start none → 2021-05-12; baseline finish none → 2021-05-17 |
| 33 | **Application Environment Set-up** |  |  |  | 151d → 165d | baseline start none → 2021-04-26; baseline finish none → 2021-05-27 |
| 34 | Development Environment Set up |  | 2021-04-27 → 2021-04-29 (+2d) | 2d → 4d | 165d → 177d | baseline start none → 2021-04-26; baseline finish none → 2021-04-29 |
| 35 | SIT Environment Set up |  |  |  | 151d → 165d | baseline start none → 2021-05-19; baseline finish none → 2021-05-20 |
| 36 | Production Environment Set up |  |  |  | 151d → 165d | baseline start none → 2021-05-24; baseline finish none → 2021-05-24 |
| 37 | UAT Environment Set up |  |  |  | 151d → 165d | baseline start none → 2021-05-26; baseline finish none → 2021-05-27 |
| 38 | **Requirement analysis of the customer** |  | 2021-06-18 → 2021-06-21 (+3d) | 17d? → 18d? | 136d → 149d | resources Josephine Joel → none; baseline start none → 2021-05-26; baseline finish none → 2021-06-21 |
| 39 | Getting an idea or overview of the website |  |  |  | 151d → 165d | baseline start none → 2021-05-26; baseline finish none → 2021-05-27 |
| 40 | Identification of Stakeholders |  |  |  | 145d → 159d | baseline start none → 2021-05-28; baseline finish none → 2021-05-28 |
| 41 | Gather requirements for the web application |  |  |  | 144d → 158d | resources Josephine Joel → Josephine Joel; Desktops; Diana James; Furniture; Laptops; Microsoft [0.1%]; Ryan Williamson; baseline start none → 2021-06-01; baseline finish none → 2021-06-02 |
| 42 | Conducting Meeting and Surveys |  |  |  | 144d → 158d | baseline start none → 2021-06-04; baseline finish none → 2021-06-04 |
| 43 | Perform Stakeholder Analysis |  |  |  | 144d → 158d | baseline start none → 2021-06-08; baseline finish none → 2021-06-08 |
| 44 | Determing Solution Approach | 2021-06-08 → 2021-06-09 (+1d) | 2021-06-09 → 2021-06-14 (+5d) |  | 143d → 154d | baseline start none → 2021-06-09; baseline finish none → 2021-06-14 |
| 45 | Finding new enhanced needs |  |  |  | 139d → 151d | resources Josephine Joel → Josephine Joel; Boniface Barrack; Desktops; Diana James; Federal Credit Union [0.1%]; Microsoft [0.1%]; Naga Srinivas; PNC Bank [0.1%]; State of Ohio [0.1%]; baseline start none → 2021-06-10; baseline finish none → 2021-06-10 |
| 46 | Creation requirements draft |  |  |  | 138d → 150d | baseline start none → 2021-06-11; baseline finish none → 2021-06-11 |
| 47 | Document those requirements into Business Requirement Document and Funtional Requirement Document i.e. FRD & BRD |  | 2021-06-16 → 2021-06-18 (+2d) | 2d → 4d | 138d → 150d | resources Josephine Joel → Josephine Joel [50%]; PNC Bank [0.1%]; baseline start none → 2021-06-15; baseline finish none → 2021-06-18 |
| 48 | Documented BRD and FRD | 2021-06-16 → 2021-06-18 (+2d) | 2021-06-16 → 2021-06-18 (+2d) |  | 139d → 151d | baseline start none → 2021-06-18; baseline finish none → 2021-06-18 |
| 49 | Business Analysis Establishment |  | 2021-06-16 → 2021-06-17 (+1d) | 1d? → 2d? | 138d → 151d | resources Josephine Joel → Josephine Joel [50%]; Laptops [500%]; baseline start none → 2021-06-16; baseline finish none → 2021-06-17 |
| 50 | Preparation of Requirement Traceability Matrix | 2021-06-17 → 2021-06-18 (+1d) | 2021-06-18 → 2021-06-21 (+3d) |  | 136d → 149d | resources Josephine Joel → Josephine Joel [50%]; Desktops; baseline start none → 2021-06-18; baseline finish none → 2021-06-21 |
| 51 | **Project Risk Analysis** |  |  |  | 128d → 142d | baseline start none → 2021-04-26; baseline finish none → 2021-06-30 |
| 52 | Analysis of risks involved |  | 2021-04-27 → 2021-04-29 (+2d) | 2d → 4d | 165d → 177d | resources Naga Srinivas; Shaun Micheals → Shaun Micheals; Microsoft [0.1%]; Ryan Williamson [50%]; baseline start none → 2021-04-26; baseline finish none → 2021-04-29 |
| 53 | Registering the risks |  |  |  | 128d → 142d | resources Naga Srinivas → Naga Srinivas [50%]; Desktops; Furniture; baseline start none → 2021-06-22; baseline finish none → 2021-06-22 |
| 54 | Documenting the risks involved |  |  |  | 128d → 142d | baseline start none → 2021-06-24; baseline finish none → 2021-06-25 |
| 55 | Development of WBS |  |  |  | 128d → 142d | baseline start none → 2021-06-29; baseline finish none → 2021-06-30 |
| 56 | Work Breakdown Structure Development |  |  |  | 129d → 143d | baseline start none → 2021-06-30; baseline finish none → 2021-06-30 |
| 57 | Project Planning Phase End |  |  |  | 129d → 143d | baseline start none → 2021-06-30; baseline finish none → 2021-06-30 |
| 58 | **Project Execution** |  |  |  |  | baseline start none → 2021-07-01; baseline finish none → 2021-10-22 |
| 59 | **Web Design Architure** |  | 2021-07-08 → 2021-07-12 (+4d) | 6d → 8d | -50d → -51d | baseline start none → 2021-07-01; baseline finish none → 2021-07-12 |
| 60 | Getting Server, memory and communication interfaces ready |  |  |  |  | resources Shaun Micheals → Shaun Micheals; Desktops; Microsoft [0.1%]; Printers; baseline start none → 2021-07-01; baseline finish none → 2021-07-05 |
| 61 | Building functionality aspects |  | 2021-07-05 → 2021-07-12 (+7d) | 2d → 4d | -46d → -51d | baseline start none → 2021-07-02; baseline finish none → 2021-07-12 |
| 62 | Building visual appearance as User Interface design |  |  |  |  | baseline start none → 2021-07-06; baseline finish none → 2021-07-08 |
| 63 | **Business Analysis** |  |  |  |  | baseline start none → 2021-07-08; baseline finish none → 2021-08-05 |
| 64 | Organizing, verifying and validating the gathered requirements |  |  |  |  | baseline start none → 2021-07-08; baseline finish none → 2021-07-12 |
| 65 | Analysis of change requirements |  |  |  |  | baseline start none → 2021-07-14; baseline finish none → 2021-07-15 |
| 66 | Translation of the business requirements into technicality for development purpose |  |  |  |  | baseline start none → 2021-07-16; baseline finish none → 2021-07-19 |
| 67 | Workshop sessions with vendors |  |  |  |  | baseline start none → 2021-07-20; baseline finish none → 2021-07-21 |
| 68 | Use Case Diagrams |  |  |  |  | baseline start none → 2021-07-22; baseline finish none → 2021-07-22 |
| 69 | Conduct Unit Testing Activites |  |  |  |  | baseline start none → 2021-07-23; baseline finish none → 2021-07-26 |
| 70 | Performance Reporting and Progress tracking |  |  |  |  | baseline start none → 2021-07-27; baseline finish none → 2021-07-30 |

| ID | Task | Start | Finish | Duration | Total float | Other |
| --- | --- | --- | --- | --- | --- | --- |
| 71 | Working on Change Requests |  |  |  |  | baseline start none → 2021-08-02; baseline finish none → 2021-08-03 |
| 72 | Updating the change documentation |  |  |  |  | baseline start none → 2021-08-04; baseline finish none → 2021-08-05 |
| 73 | **Web application Development & Testing** |  |  | 78d? → 79d? | -121d → -122d | baseline start none → 2021-07-01; baseline finish none → 2021-10-20 |
| 74 | Review of the requirements or features for development |  |  |  |  | baseline start none → 2021-07-01; baseline finish none → 2021-07-01 |
| 75 | Coding or developing the requirements which meets the acceptance critieria |  |  |  |  | baseline start none → 2021-08-09; baseline finish none → 2021-08-11 |
| 76 | Mobile application development |  |  |  |  | baseline start none → 2021-08-12; baseline finish none → 2021-08-13 |
| 77 | Performing Unit Testing |  |  |  |  | baseline start none → 2021-08-16; baseline finish none → 2021-08-17 |
| 78 | Perform Integration Tesing |  |  |  |  | baseline start none → 2021-08-18; baseline finish none → 2021-08-19 |
| 79 | Deploying the features into development envrionment and system integration test environment |  |  |  |  | resources Ryan Williamson → Ryan Williamson; Desktops; Laptops; Microsoft [0.1%]; baseline start none → 2021-08-20; baseline finish none → 2021-08-20 |
| 80 | Testing the features in development environment |  |  |  |  | baseline start none → 2021-08-24; baseline finish none → 2021-08-24 |
| 81 | Debugging the application | 2021-08-24 → 2021-08-25 (+1d) | 2021-08-24 → 2021-08-26 (+2d) | 1d? → 2d? | -82d → -84d | baseline start none → 2021-08-25; baseline finish none → 2021-08-26 |
| 82 | Deployment of features into system integration test environment |  |  |  |  | baseline start none → 2021-08-25; baseline finish none → 2021-08-25 |
| 83 | Integration of new features in the application |  |  |  |  | baseline start none → 2021-08-27; baseline finish none → 2021-08-31 |
| 84 | Deployment Accomplished |  |  |  |  | resources none → Diana James; baseline start none → 2021-09-01; baseline finish none → 2021-09-01 |
| 85 | Test plan Review |  |  |  | -102d → -103d | baseline start none → 2021-08-31; baseline finish none → 2021-08-31 |
| 86 | Preparing the test plan |  |  |  | -102d → -103d | baseline start none → 2021-09-02; baseline finish none → 2021-09-07 |
| 87 | Preparing test scenarios | 2021-09-07 → 2021-09-08 (+1d) | 2021-09-08 → 2021-09-16 (+8d) |  | -92d → -98d | baseline start none → 2021-09-08; baseline finish none → 2021-09-16 |
| 88 | Preparing the test scripts as per organization template |  |  |  | -102d → -103d | baseline start none → 2021-09-09; baseline finish none → 2021-09-15 |
| 89 | Executing the test scripts and updating the results i.e. pass or fail |  |  |  | -102d → -103d | baseline start none → 2021-09-17; baseline finish none → 2021-09-20 |
| 90 | Test result documentation process | 2021-09-22 → 2021-09-23 (+1d) | 2021-09-22 → 2021-09-23 (+1d) |  | -102d → -103d | resources Diana James → Diana James; Furniture; Laptops; Microsoft [0.1%]; baseline start none → 2021-09-23; baseline finish none → 2021-09-23 |
| 91 | Logging defects found in the application with bug severirties & priorities |  |  |  | -107d → -108d | baseline start none → 2021-09-21; baseline finish none → 2021-09-22 |
| 92 | Developers fix the issues |  |  |  | -107d → -108d | baseline start none → 2021-09-24; baseline finish none → 2021-09-27 |
| 93 | Retesting is done | 2021-09-29 → 2021-09-30 (+1d) | 2021-09-29 → 2021-09-30 (+1d) |  | -107d → -108d | baseline start none → 2021-09-30; baseline finish none → 2021-09-30 |
| 94 | Regression testing on newly deployed features |  |  |  |  | baseline start none → 2021-09-28; baseline finish none → 2021-09-28 |
| 95 | Application's functionality successful in SIT environment |  |  |  |  | resources none → Microsoft; baseline start none → 2021-09-28; baseline finish none → 2021-09-28 |
| 96 | Secuity Based Testing |  |  |  | -115d → -116d | baseline start none → 2021-09-29; baseline finish none → 2021-09-29 |
| 97 | Stress Testing |  |  |  | -115d → -116d | baseline start none → 2021-10-01; baseline finish none → 2021-10-01 |
| 98 | Performance Testing |  |  |  | -112d → -113d | baseline start none → 2021-10-06; baseline finish none → 2021-10-06 |
| 99 | Load Testing |  | 2021-10-06 → 2021-10-07 (+1d) | 1d? → 2d? | -112d → -113d | resources Diana James → Diana James [50%]; Boniface Barrack [25%]; Desktops; Furniture; Josephine Joel [25%]; Laptops; baseline start none → 2021-10-06; baseline finish none → 2021-10-07 |
| 100 | Performing UAT and coording with business users |  | 2021-10-06 → 2021-10-07 (+1d) | 2d → 3d | -117d → -118d | baseline start none → 2021-10-05; baseline finish none → 2021-10-07 |
| 101 | Making changes before pre-production |  |  |  |  | baseline start none → 2021-10-07; baseline finish none → 2021-10-07 |
| 102 | Performing Pilot testing |  |  |  |  | baseline start none → 2021-10-08; baseline finish none → 2021-10-11 |
| 103 | Training the users on the application usage |  |  |  |  | baseline start none → 2021-10-13; baseline finish none → 2021-10-15 |
| 104 | Transfer of new database structures |  |  |  |  | baseline start none → 2021-10-15; baseline finish none → 2021-10-15 |
| 105 | Database testing |  |  |  |  | baseline start none → 2021-10-19; baseline finish none → 2021-10-19 |
| 106 | Readiness Review of the application |  | 2021-10-19 → 2021-10-20 (+1d) | 1d? → 2d? | -121d → -122d | baseline start none → 2021-10-19; baseline finish none → 2021-10-20 |
| 107 | Moving the application into production environment |  |  |  |  | baseline start none → 2021-10-15; baseline finish none → 2021-10-18 |
| 108 | Project Execution Phase End |  |  |  |  | resources none → Laptops; baseline start none → 2021-10-20; baseline finish none → 2021-10-20 |
| 109 | **Project Monitoring & Controlling Phase** |  | 2021-12-10 → 2022-01-20 (+41d) | 35d? → 63d? |  | baseline start none → 2021-10-21; baseline finish none → 2021-12-10 |
| 110 | **Solution towards Application's issues** |  | 2021-11-04 → 2021-11-10 (+6d) | 11d? → 15d? |  | baseline start none → 2021-10-21; baseline finish none → 2021-11-04 |
| 111 | Monitoring key server resources for the purpose of load and usage |  |  |  | 43d → 57d | baseline start none → 2021-10-21; baseline finish none → 2021-10-22 |
| 112 | Monitoring the response and load time |  |  |  | 42d → 56d | baseline start none → 2021-10-25; baseline finish none → 2021-10-26 |
| 113 | Monitoring version and configuration changes |  |  |  | 42d → 56d | baseline start none → 2021-10-28; baseline finish none → 2021-10-29 |
| 114 | Controlling the scope of the deployed requirements |  |  |  | 41d → 55d | baseline start none → 2021-10-29; baseline finish none → 2021-11-01 |
| 115 | Tracking the performance of the application |  |  |  | 37d → 48d | baseline start none → 2021-11-02; baseline finish none → 2021-11-03 |
| 116 | Information and reporting on end user's issues in production | 2021-11-05 → 2021-11-10 (+5d) | 2021-11-05 → 2021-11-10 (+5d) |  | 37d → 48d | baseline start none → 2021-11-10; baseline finish none → 2021-11-10 |
| 117 | **Network traffic monitoring** |  |  |  |  | baseline start none → 2021-11-05; baseline finish none → 2021-11-11 |
| 118 | Monitoring, tracing and analyzing traffic data once for all |  |  |  | 34d → 48d | baseline start none → 2021-11-05; baseline finish none → 2021-11-08 |
| 119 | Identifying the major users of the network |  |  |  | 33d → 47d | baseline start none → 2021-11-09; baseline finish none → 2021-11-09 |
| 120 | Troubleshoot the issues |  |  |  | 33d → 47d | baseline start none → 2021-11-11; baseline finish none → 2021-11-11 |
| 121 | Transition support set up for users |  |  |  | 33d → 47d | baseline start none → 2021-11-11; baseline finish none → 2021-11-11 |
| 122 | **Monitoring the response time of servers** |  |  |  |  | baseline start none → 2021-11-12; baseline finish none → 2021-11-18 |
| 123 | Checking the server response time with both physically and virtually |  |  |  | 30d → 44d | baseline start none → 2021-11-12; baseline finish none → 2021-11-15 |
| 124 | Reporting from Network and database Administration |  |  |  | 29d → 43d | baseline start none → 2021-11-16; baseline finish none → 2021-11-17 |
| 125 | Isolating application Issues |  |  |  | 28d → 42d | baseline start none → 2021-11-18; baseline finish none → 2021-11-18 |
| 126 | **Identifying user feedback** |  |  |  |  | baseline start none → 2021-11-19; baseline finish none → 2021-11-24 |
| 127 | Updates on the deployments |  |  |  | 24d → 38d | baseline start none → 2021-11-19; baseline finish none → 2021-11-19 |
| 128 | Capturing and documenting issues in production |  |  |  | 24d → 38d | baseline start none → 2021-11-23; baseline finish none → 2021-11-24 |
| 129 | Ensuring issues are resolved successfully |  |  |  | 24d → 38d | baseline start none → 2021-11-24; baseline finish none → 2021-11-24 |
| 130 | **Maintaince of the application** |  |  |  |  | baseline start none → 2021-11-29; baseline finish none → 2021-12-02 |
| 131 | Minor Bug fixes for new versions |  |  |  | 20d → 34d | baseline start none → 2021-11-29; baseline finish none → 2021-11-29 |
| 132 | Updating new supporting frameworks |  |  |  | 20d → 34d | baseline start none → 2021-11-30; baseline finish none → 2021-11-30 |
| 133 | Inserting or Importing new data for enhancements |  |  |  | 20d → 34d | resources Shaun Micheals → Shaun Micheals [66.7%]; Desktops; Josephine Joel [33.3%]; Laptops; Microsoft [0.1%]; baseline start none → 2021-12-01; baseline finish none → 2021-12-01 |
| 134 | Confirmation on the service level agreements |  |  |  | 20d → 34d | baseline start none → 2021-12-02; baseline finish none → 2021-12-02 |
| 135 | **Post production support** |  | 2021-12-10 → 2022-01-20 (+41d) | 6d? → 34d? |  | baseline start none → 2021-05-03; baseline finish none → 2022-01-03 |
| 136 | Retesting the new version changes |  |  |  | 15d → 29d | baseline start none → 2021-10-21; baseline finish none → 2021-10-21 |
| 137 | Approval of new version changes |  |  |  | 15d → 29d | baseline start none → 2021-12-06; baseline finish none → 2021-12-06 |
| 138 | Version Approval |  |  |  | 15d → 29d | baseline start none → 2021-12-06; baseline finish none → 2021-12-06 |
| 139 | Implementing critical changes |  |  |  | 15d → 29d | baseline start none → 2021-12-07; baseline finish none → 2021-12-07 |
| 140 | Regulatory maintainence and Compliances |  |  |  | 15d → 29d | baseline start none → 2021-12-08; baseline finish none → 2021-12-09 |

| ID | Task | Start | Finish | Duration | Total float | Other |
| --- | --- | --- | --- | --- | --- | --- |
| 141 | Residual Error fixes |  |  |  | 14d → 28d | baseline start none → 2021-12-10; baseline finish none → 2021-12-10 |
| 142 | **Montly Status Meeting** |  |  |  |  | baseline start none → 2021-05-03; baseline finish none → 2021-12-03 |
| 143 | Montly Status Meeting 1 |  |  | 1d → 0.67d | 162d → 161.33d | resources Boniface Barrack → Naga Srinivas [50%]; Laptops [50%]; baseline start none → 2021-05-03; baseline finish none → 2021-05-03 |
| 144 | Montly Status Meeting 2 | 2021-05-04 → 2021-05-03 (-1d) |  |  | 162d → 161.33d | baseline start none → 2021-05-03; baseline finish none → 2021-05-04 |
| 145 | Montly Status Meeting 3 | 2021-05-05 → 2021-05-04 (-1d) | 2021-05-05 → 2021-05-06 (+1d) | 1d → 2d | 162d → 161.33d | resources Boniface Barrack → Boniface Barrack [50%]; Naga Srinivas [50%]; baseline start none → 2021-05-04; baseline finish none → 2021-05-06 |
| 146 | Montly Status Meeting 4 |  | 2021-05-06 → 2021-05-07 (+1d) |  | 162d → 161.33d | baseline start none → 2021-05-06; baseline finish none → 2021-05-07 |
| 147 | Montly Status Meeting 5 |  |  |  | 76d → 90d | resources Boniface Barrack → Boniface Barrack [50%]; Desktops; Laptops; Microsoft [0.1%]; baseline start none → 2021-09-08; baseline finish none → 2021-09-08 |
| 148 | Montly Status Meeting 6 | 2021-12-29 → 2022-01-18 (+20d) | 2021-12-29 → 2022-01-18 (+20d) |  |  | resources Boniface Barrack → Diana James; baseline start none → 2021-12-30; baseline finish none → 2021-12-30 |
| 149 | Montly Status Meeting 7 | 2021-12-30 → 2022-01-19 (+20d) | 2021-12-30 → 2022-01-19 (+20d) |  |  | resources Boniface Barrack → Diana James; baseline start none → 2021-12-31; baseline finish none → 2021-12-31 |
| 150 | Montly Status Meeting 8 | 2021-12-31 → 2022-01-20 (+20d) | 2021-12-31 → 2022-01-20 (+20d) |  |  | resources Boniface Barrack → Diana James; baseline start none → 2022-01-03; baseline finish none → 2022-01-03 |
| 151 | Project Monitoring & Controlling Phase End |  |  |  | 15d → 29d | resources none → Desktops; baseline start none → 2021-12-10; baseline finish none → 2021-12-10 |
| 152 | **Project Closing Phase** | 2021-12-13 → 2021-04-05 (-252d) | 2021-12-31 → 2022-01-20 (+20d) | 14d? → 204d? | none → 0d | baseline start none → 2021-04-05; baseline finish none → 2022-01-03 |
| 153 | **Evaluation Reporting** |  | 2021-12-17 → 2021-12-22 (+5d) | 5d? → 8d? | 8d → 19d | baseline start none → 2021-12-13; baseline finish none → 2021-12-22 |
| 154 | Collection and Evaluation of performances of the application |  |  |  | 11d → 23d | baseline start none → 2021-12-13; baseline finish none → 2021-12-14 |
| 155 | Formal Acceptability from the users | 2021-12-15 → 2021-12-16 (+1d) | 2021-12-15 → 2021-12-17 (+2d) | 1d? → 2d? | 10d → 22d | baseline start none → 2021-12-16; baseline finish none → 2021-12-17 |
| 156 | Lessons learnt document analysis | 2021-12-16 → 2021-12-20 (+4d) | 2021-12-17 → 2021-12-22 (+5d) |  | 8d → 19d | baseline start none → 2021-12-20; baseline finish none → 2021-12-22 |
| 157 | **Benfit Analysis Reporting** | 2021-12-13 → 2021-04-05 (-252d) |  | 7d → 183d | 5d → 19d | baseline start none → 2021-04-05; baseline finish none → 2021-12-21 |
| 158 | Highlighting of web application features | 2021-12-13 → 2021-04-05 (-252d) | 2021-12-13 → 2021-04-05 (-252d) |  | 11d → 201d | baseline start none → 2021-04-05; baseline finish none → 2021-04-05 |
| 159 | Brief summary of final product or service |  |  |  | 5d → 19d | baseline start none → 2021-12-21; baseline finish none → 2021-12-21 |
| 160 | **Project Status Reporting** | 2021-12-13 → 2021-12-22 (+9d) | 2021-12-31 → 2022-01-20 (+20d) | 14d? → 21d? | 0d → none | baseline start none → 2022-01-20; baseline finish none → 2022-01-03 |
| 161 | Operational and Support documentation | 2021-12-13 → 2021-12-22 (+9d) | 2021-12-13 → 2021-12-22 (+9d) | 1d? → 1d | 10d → 15d | baseline start none → 2021-12-22; baseline finish none → 2021-04-05 |
| 162 | Phase closure documentation | 2021-12-15 → 2021-12-27 (+12d) | 2021-12-15 → 2021-12-28 (+13d) | 1d? → 2d? | 10d → 15d | constraint none → start no earlier than 2021-12-23; resources Naga Srinivas → Naga Srinivas [50%]; Boniface Barrack [50%]; baseline start none → 2021-12-29; baseline finish none → 2021-04-08 |
| 164 | Scope, quality and objective reporting | 2021-12-15 → 2022-01-11 (+27d) | 2021-12-16 → 2022-01-13 (+28d) | 2d → 3d | 10d → 5d | constraint none → start no earlier than 2022-01-11; baseline start none → 2021-04-15; baseline finish none → 2021-04-16 |
| 165 | Genrating Monthly and weekly status reports | 2021-12-29 → 2022-01-14 (+16d) | 2021-12-29 → 2022-01-17 (+19d) | 1d → 2d | 2d → 3d | constraint start no earlier than 2021-12-29 → start no earlier than 2022-01-14; baseline start none → 2021-12-29; baseline finish none → 2021-12-29 |
| 166 | Successful Project Reporting | 2021-12-29 → 2022-01-17 (+19d) | 2021-12-29 → 2022-01-17 (+19d) |  | 3d → 4d | constraint start no earlier than 2021-12-29 → start no earlier than 2022-01-17; resources Naga Srinivas → Naga Srinivas [50%]; Boniface Barrack [50%]; baseline start none → 2021-12-29; baseline finish none → 2021-12-29 |
| 167 | Project Review Documentation | 2021-12-30 → 2022-01-18 (+19d) | 2021-12-30 → 2022-01-18 (+19d) |  |  | constraint start no earlier than 2021-12-30 → start no earlier than 2022-01-18; baseline start none → 2021-12-30; baseline finish none → 2021-12-30 |
| 168 | Release the project Resoures | 2021-12-31 → 2022-01-19 (+19d) | 2021-12-31 → 2022-01-20 (+20d) | 1d? → 2d? |  | constraint start no earlier than 2021-12-31 → start no earlier than 2022-01-19; resources Boniface Barrack → Boniface Barrack [50%]; Naga Srinivas [50%]; baseline start none → 2021-12-31; baseline finish none → 2022-01-03 |
| 169 | Project Closing Phase End | 2021-12-31 → 2022-01-20 (+20d) | 2021-12-31 → 2022-01-20 (+20d) |  |  | constraint start no earlier than 2021-12-31 → start no earlier than 2022-01-20; resources none → Microsoft; baseline start none → 2021-12-31; baseline finish none → 2021-12-31 |
| 170 | **Contingency** |  |  |  |  | baseline start none → 2021-09-20; baseline finish none → 2021-12-30 |
| 171 | Contingency #1 |  |  |  | 35d → 49d | baseline start none → 2021-09-20; baseline finish none → 2021-11-01 |
| 172 | Contingency #2 |  |  |  | 35d → 49d | baseline start none → 2021-11-02; baseline finish none → 2021-11-08 |
| 173 | Contingency #3 |  |  |  | 1d → 15d | baseline start none → 2021-12-30; baseline finish none → 2021-12-30 |
